# 3GPP_Release-2000

Schedule from MS Project, 2000-01-03 to 2008-07-11, A marks actual dates.

## Calendars

- Standard: Mon-Fri 08:00-12:00, 13:00-17:00; Sat-Sun off.

## Resources

| Resource |
| --- |
| NP |
| N1 |
| N2 |
| N3 |
| N4 |
| N5 |
| TP |
| T1 |
| T2 |
| T3 |
| RP |
| R1 |
| R2 |
| R3 |
| R4 |
| SP |
| S1 |
| S2 |
| S3 |
| S4 |
| S5 |
| PCG |
| GP |
| No |
| CN4 |
| ? |
| WG G2 |
| G2 |
| G1 |
| G4 |
| G3 |
| All |
| Generic |
| MLST |
| G5 |
| S3; G2 |
| WG T2 |
| GP;G1 |
| G4;G5 |
| OMA |
| GP-G2 |
| Yes |
| GP; |
| N4; |
| GP; N1 |
| CT5 |
| C5 |
| C1 |
| C4 |
| C3 |
| C6 |
| G1; |
| 4 |
| ct |
| c;s;r |
| CT;RAN;SA |
| G2; |
| G1; G3 |

## Schedule

| ID | WBS | Task | Type | Duration | Start | Finish | Complete | Remaining | Baseline start | Baseline finish | Baseline duration | Total slack | Constraint | Resources | Work | Actual work | Text9 | Text6 | Text1 | Text4 | Text5 | Text7 | Text8 | Text12 |
| --- | --- | --- | --- | --- | --- | --- | --- | --- | --- | --- | --- | --- | --- | --- | --- | --- | --- | --- | --- | --- | --- | --- | --- | --- |
| 1 | 1 | VERSION 2006 July 20th |  | 1d | 2000-01-03 | 2000-01-03 |  |  | 2000-01-03 | 2000-01-03 | 1d | 2224d |  |  |  |  | 2044 |  |  |  |  |  |  |  |
| 2 | 2 | "CTRL + a" to display all the 3GPP fields |  | 1d | 2000-01-03 | 2000-01-03 |  |  | 2000-01-03 | 2000-01-03 | 1d | 2009d |  |  |  |  | 1462 |  |  |  |  |  |  |  |
| 3 | 3 | Content of Rel-7 (frozen) and Rel-8 (not frozen) |  | 1d | 2000-01-03 | 2000-01-03 |  |  | 2000-01-03 | 2000-01-03 | 1d | 2224d |  |  |  |  | 2058 |  |  |  |  |  |  |  |
| 5 | 4 | Rel-7 Features |  | 1d? | 2000-01-03 | 2000-01-03 |  |  | 2000-01-03 | 2000-01-03 | 1d? | 2009d |  | CT;RAN;SA | 8h |  |  | Rel-7 |  |  |  |  |  |  |
| 6 | 8.5 | **Multiple Input Multiple Output antennas (MIMO)** |  | 850d? | 2003-03-14 A | 2006-06-15 | 18% | 696.97d? | 2003-03-14 | 2006-06-15 | 850d? | 541d |  | R1 | 30360h | 6340.8h | 2468 | Rel-7 | MIMO | Howard Huang, Lucent | hchuang@lucent.com | TSG | Cesar |  |
| 7 | 5.1 | MIMO - Physical layer |  | 720d? | 2003-09-12 A | 2006-06-15 | 70% | 216d? | 2003-09-12 | 2006-06-15 | 720d? | 541d | finish no earlier than 2006-06-15 | R1 | 5760h | 4032h |  | Rel-7 | MIMO-Phys | Howard Huang, Lucent | hchuang@lucent.com | TSG | MCC_RAN |  |
| 8 | 5.2 | MIMO - Layer 2,3 aspects |  | 720d? | 2003-09-12 | 2006-06-15 |  |  | 2003-09-12 | 2006-06-15 | 720d? | 326d | finish no earlier than 2006-06-15 | R2 | 5760h |  |  | Rel-7 | MIMO-L23 | Howard Huang, Lucent | hchuang@lucent.com | TSG | MCC_RAN |  |
| 9 | 5.3 | MIMO - Iub/Iur Protocol Aspects |  | 850d? | 2003-03-14 | 2006-06-15 |  |  | 2003-03-14 | 2006-06-15 | 850d? | 326d | finish no earlier than 2006-06-15 | R3 | 6800h |  |  | Rel-7 | MIMO-IurIub | Howard Huang, Lucent | hchuang@lucent.com | TSG | MCC_RAN |  |
| 10 | 5.4 | MIMO - RF Radio Transmission/Reception, System Performance Requirements and Conformance Testing |  | 655d? | 2003-12-12 A | 2006-06-15 | 4% | 628.8d? | 2003-12-12 | 2006-06-15 | 655d? | 326d | finish no earlier than 2006-06-15 | R4 | 5240h | 209.6h |  | Rel-7 | MIMO-RF | Man Hung Ng, Lucent | ngm@lucent.com | TSG | MCC_RAN |  |
| 11 | 6 | **Rel-7 Improvements of the Radio Interface** |  | 652d? | 2004-09-15 A | 2007-03-15 | 61% | 253.38d? | 2004-09-15 | 2006-12-15 | 588d? | 346d |  | RP | 30864h | 16592.8h |  | Rel-7 | RInImp |  |  |  | Cesar |  |
| 12 | 6.1 | Extended UMTS 1.7/2.1 GHz |  | 198d? | 2006-03-15 A | 2006-12-15 | 25% | 148.5d? | 2006-03-15 | 2006-12-15 | 198d? | 410d | finish no earlier than 2006-12-15 | R4 | 1584h | 396h |  | Rel-7 | RInImp-UMTS1721Ext | Johan Sköld | johan.skold@ericsson.com |  | MCC_RAN |  |
| 13 | 6.2 | UMTS 2.6 GHz 7.68 MHz TDD |  | 67d? | 2006-06-15 | 2006-09-15 |  |  |  |  |  | 475d | finish no earlier than 2006-09-15 | R4 | 536h |  |  |  | RInImp-UMTS26VHCRTDD | Shin Horng Wong , IPWireless | shwong@ipwireless.com |  | MCC_RAN |  |
| 14 | 6.3 | UMTS 2.6 GHz |  | 195d? | 2004-09-15 A | 2005-06-14 A | 100% |  | 2004-09-15 | 2005-06-14 | 195d? |  | finish no earlier than 2005-06-14 | R4 | 1560h | 1560h |  | Rel-7 | RInImp-UMTS2600 | Jussi Numminen, Nokia | jussi.numminen@nokia.com | TSG | Cesar |  |
| 15 | 6.4 | UMTS 2.6 GHz TDD |  | 261d? | 2004-12-15 A | 2005-12-14 A | 100% |  | 2004-12-15 | 2005-12-14 | 261d? |  | finish no earlier than 2005-12-15 | R4 | 2088h | 2088h |  | Rel-7 | RInImp-UMTS2600TDD | Shin Horng Wong (IPWireless) | shwong@IPWIRELESS.COM | TSG | MCC_RAN |  |
| 16 | 6.5 | UMTS 900 MHz |  | 261d? | 2004-12-15 A | 2005-12-14 A | 100% |  | 2004-12-15 | 2005-12-14 | 261d? |  | finish no earlier than 2005-12-15 | R4 | 2088h | 2088h |  | Rel-7 | RInImp-UMTS900 | Yannick Li (Nortel) | yli@nortelnetworks.com | TSG | MCC_RAN |  |
| 17 | 6.6 | UMTS 1700 MHz |  | 197d? | 2005-03-15 A | 2005-12-14 A | 100% |  | 2005-03-15 | 2005-12-14 | 197d? |  | finish no earlier than 2005-12-15 | R4 | 1576h | 1576h |  | Rel-7 | RInImp-UMTS1700 | Takehiro Nakamura | NTT DoCoMo | TSG | MCC_RAN |  |
| 18 | 6.7 | UE Antenna Performance Evaluation Method and Requirements |  | 523d? | 2004-12-15 A | 2006-12-15 | 75% | 130.75d? | 2004-12-15 | 2006-06-15 | 392d? | 410d | finish no earlier than 2006-12-15 | R4 | 4184h | 3138h |  | Rel-7 | RInImp-UEAnt | Christian Bergljung (TeliaSonera) | Christian.Bergljung@TeliaSonera.com | TSG | MCC_RAN |  |
| 19 | 6.8 | Improved Performance Requirements for HSDPA UE based on Rx Diversity (type 1) & LMMSE equalizer (type 2) | milestone | 0d? | 2005-03-15 A | 2005-03-15 A | 100% |  | 2005-03-15 | 2005-03-15 | 0d? |  | finish no earlier than 2005-03-15 | R4 |  |  |  | Rel-7 | RInImp-HSPerf-Type3 | Marc Grant | marc.grant@cingular.com | TSG | MCC_RAN |  |
| 20 | 6.9 | **Additional minimum UE performance requirement for non-HSDPA channels based on type 1 enhanced receiver (Rx Diversity)** |  | 391d? | 2005-09-15 A | 2007-03-15 | 45% | 213.72d? | 2005-09-15 | 2006-06-15 | 195d? | 346d |  | R4 | 8880h | 3380.08h |  | Rel-7 | RInImp-RxDiv | Serge Willenegger | sergew@qualcomm.com |  | MCC_RAN |  |
| 21 | 6.9.1 | Additional minimum UE performance requirement for DL physical channels in support of DCH/HS-DSCH operation based on type 1 enhanced receiver (RX-Diversity) |  | 195d? | 2005-09-15 A | 2006-06-14 A | 100% |  | 2005-09-15 | 2006-06-15 | 195d? |  | finish no earlier than 2006-06-15 | R4 | 1560h | 1560h |  | Rel-7 | RInImp-RxDiv-DCH | Marc Grant | marc.grant@cingular.com | TSG | MCC_RAN |  |
| 22 | 6.9.2 | Additional minimum UE performance requirement for downlink physical channels in support of MTCH and MCCH operation based on type 1 enhanced receiver (Rx-Diversity) |  | 262d? | 2006-03-15 A | 2007-03-15 | 25% | 196.5d? | 2006-03-15 | 2006-03-15 | 1d? | 346d | finish no earlier than 2007-03-15 | R4 | 2096h | 524h |  | Rel-7 | RInImp-RxDiv-MBMS | Serge Willenegger | sergew@qualcomm.com |  | MCC_RAN |  |
| 23 | 6.9.3 | Additional minimum UE performance requirement for downlink physical channels in support of E-DCH operation based on type 1 enhanced receiver (Rx-Diversity) |  | 262d? | 2006-03-15 A | 2007-03-15 | 25% | 196.5d? | 2006-03-15 | 2006-03-15 | 1d? | 346d | finish no earlier than 2007-03-15 | R4 | 2096h | 524h |  | Rel-7 | RInImp-RxDiv-EDCH | Serge Willenegger | sergew@qualcomm.com |  | MCC_RAN |  |
| 24 | 6.10 | Improved support of gaming over HSDPA/EDCH |  | 262d? | 2005-12-15 A | 2006-12-15 | 15% | 222.7d? | 2005-12-15 | 2006-12-15 | 262d? | 410d | finish no earlier than 2006-12-15 | R2 | 2096h | 314.4h |  | Rel-7 | RInImp-Gaming | Don Zelmer, Cingular | don.zelmer@cingular.com |  | MCC_RAN |  |
| 25 | 6.11 | Interface to control Tower Mounted Amplifiers (TMAs) |  | 132d? | 2006-06-15 | 2006-12-15 |  |  |  |  |  | 410d | finish no earlier than 2006-12-15 | R3 | 1056h |  |  | Rel-7 | RInImp-TMA | Alexej Kulakov, Vodafone |  |  | MCC_RAN |  |
| 26 | 6.12 | Deleted (not approved at PCG) - UMTS 2.6 GHz FDD DL External | milestone | 0d? | 2005-09-15 A | 2005-09-15 A | 100% |  | 2005-09-15 | 2005-09-15 | 0d? |  | finish no earlier than 2005-09-15 | R4 |  |  |  | Rel-7 | RInImp-UMTS2600Ext | Han van Bussel | han.van.bussel@t-mobile.de | TSG | MCC_RAN | RP-31 |

Notes:
- 6: Text3: TR25.876,TR25.996
- 7: Text3: 25.211, 25.212, 25.213, 25.214, 25.215, 25.221, 25
- 8: Text3: TR 25.876
- 12: Text3: 25.806, 25.101, 25.104, 25.133, 24.141, 25.331, 25.306, 25.307, 25.423, 25.461, 25.463, 34.121
- 13: Text3: 25.102, 25.105, 25.123, 25.113, 25.142, 34.124
- 14: Approved at RP#25 as RP-040377 / Text3: TS25.101, TS25.104, TS25.133, TS25.141, TS25.331, TS25.942, TS25.306, TS25.307, TS34.121
- 15: Text3: 25.102, 25.105, 25.113, 25.123, 25.142, 25.331, 25.942, 25.306, 25.307, 34.122, 34.124
- 16: Text3: 25.101, 25.104, 25.113, 25.133, 25.141, 25.331, 25.942, 25.306, 25.307, 34.121
- 17: Text3: 25.101, 25.104, 25.113, 25.133, 25.141, 25.306, 25.307, 25.331, 34.121
- 18: Text3: TS25.101
- 19: Text3: 25.101
- 21: Text3: 25.101
- 22: Text3: 25.101
- 23: Text3: 25.101
- 26: This item was conditionnaly approved pending decision of PCG 16 who decided not to approve it / Text3: 25.101, 25.104, 25.133, 25.141, 25.331, 25.942, 25.306, 25.307, 34.121

| ID | WBS | Task | Duration | Start | Finish | Complete | Remaining | Baseline start | Baseline finish | Baseline duration | Total slack | Constraint | Resources | Work | Actual work | Text1 | Text4 | Text5 | Text6 | Text7 | Text8 |
| --- | --- | --- | --- | --- | --- | --- | --- | --- | --- | --- | --- | --- | --- | --- | --- | --- | --- | --- | --- | --- | --- |
| 27 | 7 | **7.68Mcps TDD option** | 457d? | 2004-09-15 A | 2006-06-15 | 93% | 33.07d? | 2004-09-15 | 2006-06-15 | 457d? | 541d |  | RP | 19824h | 16376.2h | VHCRTDD | Martin Beale, IPWireless | mbeale@ipwireless.com | Rel-7 | TSG | Cesar |
| 28 | 7.1 | VHCRTDD: Stage 2 | 391d? | 2004-09-15 A | 2006-03-15 A | 100% |  | 2004-09-15 | 2006-03-15 | 391d? |  | finish no earlier than 2006-03-15 | R1 | 3128h | 3128h | VHCRTDD-Stage2 | Martin Beale, IPWireless | mbeale@ipwireless.com | Rel-7 | TSG | MCC_RAN |
| 29 | 7.2 | VHCRTDD: Physical Layer | 391d? | 2004-09-15 A | 2006-03-15 A | 100% |  | 2004-09-15 | 2006-03-15 | 391d? |  | finish no earlier than 2006-03-15 | R1 | 3128h | 3128h | VHCRTDD-Phys | Martin Beale, IPWireless | mbeale@ipwireless.com | Rel-7 | TSG | MCC_RAN |
| 30 | 7.3 | VHCRTDD: Layer 2 and layer 3 protocol aspects | 391d? | 2004-09-15 A | 2006-03-15 A | 100% |  | 2004-09-15 | 2006-03-15 | 391d? |  | finish no earlier than 2006-03-15 | R2 | 3128h | 3128h | VHCRTDD-L23 | Derek Richards, IPWireless | drichards@ipwireless.com | Rel-7 | TSG | MCC_RAN |
| 31 | 7.4 | VHCRTDD: UTRAN Iub/Iur Protocol Aspects | 391d? | 2004-09-15 A | 2006-03-15 A | 100% |  | 2004-09-15 | 2006-03-15 | 391d? |  | finish no earlier than 2006-03-15 | R3 | 3128h | 3128h | VHCRTDD-IurIub | Peter Legg, IPWireless | plegg@ipwireless.com | Rel-7 | TSG | MCC_RAN |
| 32 | 7.5 | VHCRTDD: RF Radio Transmission/ Reception, System Performance Requirements and Conformance Testing | 457d? | 2004-09-15 A | 2006-06-15 | 68% | 146.24d? | 2004-09-15 | 2006-06-15 | 457d? | 456d | finish no earlier than 2006-06-15 | R4 | 3656h | 2486.08h | VHCRTDD-RF | Shin Horng Wong | shwong@ipwireless.com | Rel-7 | TSG | MCC_RAN |
| 33 | 8 | **Rel-7 RAN improvements** | 523d? | 2004-12-15 A | 2006-12-15 | 66% | 179.94d? | 2004-12-15 | 2006-12-15 | 523d? | 410d |  | RP | 19952h | 11035.5h | RANimp |  |  | Rel-7 | TSG | MCC_RAN |
| 34 | 8.1 | Optimisation of channelisation code utilisation for 1.28 Mcps TDD | 458d? | 2004-12-15 A | 2006-09-15 | 85% | 68.7d? | 2004-12-15 | 2006-06-15 | 392d? | 475d | finish no earlier than 2006-09-15 | R1 | 3664h | 3114.4h | RANimp-RABSE-CodOptLCRTDD | Ka Leong Lo | kaleong.lo@utstar.com | Rel-7 | TSG | MCC_RAN |
| 35 | 8.2 | Delay optimisation for procedures applicable to CS and PS Connections | 394d? | 2005-03-15 A | 2006-09-15 | 40% | 236.4d? | 2005-03-15 | 2006-09-15 | 394d? | 475d | finish no earlier than 2006-09-15 | R2 | 3152h | 1260.8h | RANimp-DelayOpt | Juho Pirskanen | juho.pirskanen@nokia.com | Rel-7 | TSG | MCC_RAN |
| 36 | 8.3 | UE Performance Requirements for MBMS (TDD) | 328d? | 2005-03-15 A | 2006-06-15 | 99% | 3.28d? | 2005-03-15 | 2006-06-15 | 328d? | 541d | finish no earlier than 2006-06-15 | R4 | 2624h | 2597.76h | MBMS-RAN-RF-TDD | Shin Horng Wong | shwong@ipwireless.com | Rel-7 | TSG | MCC_RAN |
| 37 | 8.4 | Continuous connectivity for packet data users | 460d? | 2005-03-14 A | 2006-12-15 | 60% | 184d? | 2005-03-14 | 2005-09-15 | 134d? | 410d | finish no earlier than 2006-12-15 | R1 | 3680h | 2208h | RANimp-CPC | Joern Krause | Joern.Krause@siemens.com | Rel-7 | TSG | MCC_RAN |
| 38 | 8.5 | Extended WCDMA Cell Range | 133d? | 2006-03-15 A | 2006-09-15 | 72% | 37.24d? | 2006-03-15 | 2006-09-15 | 133d? | 475d | finish no earlier than 2006-09-15 | R3 | 1064h | 766.08h | RANimp-ExtCell | Ericsson |  | Rel-7 |  | MCC_RAN |
| 39 | 8.6 | 7.68 Mcps TDD Enhanced Uplink | 198d? | 2006-03-15 A | 2006-12-15 | 25% | 148.5d? | 2006-03-15 | 2006-12-15 | 198d? | 410d | finish no earlier than 2006-12-15 | R1 | 1584h | 396h | RANimp-VHCRTDD-EDCH | Nicholas Anderson | nanderson@ipwireless.com | Rel-7 |  | MCC_RAN |
| 40 | 9 | **3.84 Mcps TDD Enhanced Uplink** | 394d? | 2005-03-15 A | 2006-09-15 | 77% | 89.68d? | 2005-03-15 | 2006-09-15 | 394d? | 475d |  | RP | 18384h | 12196h | EDCHTDD | Nicholas Anderson | nanderson@ipwireless.com | Rel-7 | TSG | MCC_RAN |
| 41 | 9.1 | EDCHTDD: Stage 2 | 328d? | 2005-03-15 A | 2006-06-15 A | 100% |  | 2005-03-15 | 2006-06-15 | 328d? |  | finish no earlier than 2006-06-15 | R2 | 2624h | 2624h | EDCHTDD-Stage2 | Nicholas Anderson | nanderson@ipwireless.com | Rel-7 | TSG | MCC_RAN |
| 42 | 9.2 | EDCHTDD: Physical Layer | 394d? | 2005-03-15 A | 2006-09-15 | 95% | 19.7d? | 2005-03-15 | 2006-06-15 | 328d? | 475d | finish no earlier than 2006-09-15 | R1 | 3152h | 2994.4h | EDCHTDD-Phys | Nicholas Anderson | nanderson@ipwireless.com | Rel-7 | TSG | MCC_RAN |
| 43 | 9.3 | EDCHTDD: Layer 2 and 3 Protocol Aspects | 394d? | 2005-03-15 A | 2006-09-15 | 95% | 19.7d? | 2005-03-15 | 2006-06-15 | 328d? | 475d | finish no earlier than 2006-09-15 | R2 | 3152h | 2994.4h | EDCHTDD-L23 | Derek Richards | drichards@ipwireless.com | Rel-7 | TSG | MCC_RAN |
| 44 | 9.4 | EDCHTDD: UTRAN Iub/Iur Protocol Aspects | 394d? | 2005-03-15 A | 2006-09-15 | 75% | 98.5d? | 2005-03-15 | 2006-09-15 | 394d? | 475d | finish no earlier than 2006-09-15 | R3 | 3152h | 2364h | EDCHTDD-IurIub | Jim Miller | jim.miller@interdigital.com | Rel-7 | TSG | MCC_RAN |
| 45 | 9.5 | EDCHTDD: RF Radio Transmission/ Reception, System Performance Requirements and Conformance Testing | 394d? | 2005-03-15 A | 2006-09-15 | 25% | 295.5d? | 2005-03-15 | 2006-09-15 | 394d? | 475d | finish no earlier than 2006-09-15 | R4 | 3152h | 788h | EDCHTDD-RF | Shin Horng Wong | shwong@ipwireless.com | Rel-7 | TSG | MCC_RAN |
| 46 | 10 | **1.28 Mcps TDD Enhanced Uplink** | 262d? | 2006-03-15 A | 2007-03-15 | 12% | 231.7d? | 2006-03-15 | 2007-03-15 | 262d? | 346d |  | RP | 8944h | 1034.41h | LCRTDD-EDCH | Haijing Hu (CATT) |  | Rel-7 |  | MCC_RAN |
| 47 | 10.1 | 1.28 Mcps TDD Enhanced Uplink: Physical Layer | 198d? | 2006-03-15 A | 2006-12-15 | 10% | 178.2d? | 2006-03-15 | 2006-12-15 | 198d? | 410d | finish no earlier than 2006-12-15 | R1 | 1584h | 158.4h | LCRTDD-EDCH-Phys | Ke Wang (CATT) |  | Rel-7 |  | MCC_RAN |
| 48 | 10.2 | 1.28 Mcps TDD Enhanced Uplink: Layer 2 and 3 Protocol Aspects | 198d? | 2006-03-15 A | 2006-12-15 | 35% | 128.7d? | 2006-03-15 | 2006-12-15 | 198d? | 410d | finish no earlier than 2006-12-15 | R2 | 1584h | 554.4h | LCRTDD-EDCH-L23 | Haiyang Quan (CATT) |  | Rel-7 |  | MCC_RAN |
| 49 | 10.3 | 1.28 Mcps TDD Enhanced Uplink: UTRAN Iub/Iur Protocol Aspects | 198d? | 2006-03-15 A | 2006-12-15 | 5% | 188.1d? | 2006-03-15 | 2006-12-15 | 198d? | 410d | finish no earlier than 2006-12-15 | R3 | 1584h | 79.2h | LCRTDD-EDCH-IubIur | Yincheng Zhang (CATT) |  | Rel-7 |  | MCC_RAN |
| 50 | 10.4 | 1.28 Mcps TDD Enhanced Uplink: RF Radio Transmission/ Reception, System Performance Requirements and Conformance Testing | 262d? | 2006-03-15 | 2007-03-15 |  |  | 2006-03-15 | 2007-03-15 | 262d? | 346d | finish no earlier than 2007-03-15 | R4 | 2096h |  | LCRTDD-EDCH-RF | Yuexia Song (CATT) |  | Rel-7 |  | MCC_RAN |
| 51 | 11 | 3G Long Term Evolution | 457d? | 2006-06-15 | 2008-03-14 |  |  |  |  |  | 85d | finish no earlier than 2008-03-14 | RP | 3656h |  | LTE | Takehiro Nakamura (NTT DoCoMo) |  | Rel-7 |  | MCC_RAN |

Notes:
- 27: Approved at RP#25 as RP-040365
- 28: Text3: TS25.202
- 29: Text3: TS25.221, TS25.222, TS25.223, TS25.224,TS25.225
- 30: Text3: TS25.301, TS25.302, TS25.305, TS25.306, TS25.321, TS25.331
- 31: Text3: TS25.401, TS25.420, TS25.423, TS25.425, TS25.427, TS25.430, TS25.433, TS25.435
- 32: Text3: TS25.102, TS25.105, TS25.123, TS25.133, TS25.142
- 33: Generic feature
- 35: Text3: TS25.321, TS25.322, TS25.331
- 36: Text3: TS25.102, TS25.123
- 38: Text3: 25.133, 25.423, 25.425, 25.433, 25.435, 25.453, 25.331
- 39: Text3: 25.201, 25.202, 25.221, 25.222, 25.223, 25.224, 25.225, 25.331, 23.321, 25.306, 25.302, 25.401, 25.420, 25.423, 25.427, 25.433, 25.102, 25.105, 25.142
- 42: Text3: TS25.201, TS25.221,TS25.222, TS25.223, TS25.224, TS25.225
- 43: Text3: TS25.301, TS25.302, TS25.306, TS25.321, TS25.331
- 44: Text3: TS25.401, TS25.420, TS25.423, TS25.427, TS25.430, TS25.433, TS25.435
- 45: Text3: TS25.102, TS25.105, TS25.123, TS25.142
- 47: Text3: 25.201, 25.221, 25.222, 25.223, 25.224, 25.225
- 48: Text3: 25.301, 25.302, 25.306, 25.321, 25.331
- 49: Text3: 25.401, 25.420, 25.423, 25.425, 25.427, 25.430, 25.433, 25.435
- 50: Text3: 25.102, 25.105, 25.123, 25.142

| ID | WBS | Task | Type | Duration | Start | Finish | Complete | Remaining | Baseline start | Baseline finish | Baseline duration | Total slack | Constraint | Resources | Work | Actual work | Text1 | Text4 | Text6 | Text7 | Text8 | Text2 | Text3 | Text9 | Text5 | Text12 |
| --- | --- | --- | --- | --- | --- | --- | --- | --- | --- | --- | --- | --- | --- | --- | --- | --- | --- | --- | --- | --- | --- | --- | --- | --- | --- | --- |
| 52 | 12 | **PS domain and IMS impacts for supporting IMS Emergency calls** |  | 1565d? | 2000-09-18 A | 2006-09-15 | 77% | 367.73d? | 2000-09-18 | 2006-09-15 | 1565d? | 475d |  | S2 | 38597h | 28735.8h | EMC1 | Rainer Liebhart | Rel-7 | TSG | Maurice |  |  |  |  |  |
| 53 | 10.1.1 | Service Requirements for IP-based emergency calls |  | 985d | 2000-09-18 A | 2004-06-25 A | 100% |  | 2000-09-18 | 2004-06-25 | 985d |  | finish no earlier than 2004-06-25 | S1 | 7880h | 7880h |  |  | Rel-7 |  |  | CCaR | 22.976 | 1314 |  |  |
| 54 | 12.2 | Study on Stage 2 for IMS-level solution |  | 668d? | 2003-02-26 A | 2005-09-16 A | 100% |  | 2003-02-26 | 2005-09-16 | 668d? |  | finish no earlier than 2005-09-16 | S2 | 5344h | 5344h |  | Rainer Liebhart, Siemenws | Rel-7 | TSG |  |  | 23.228, 23.060, 23.002 |  |  |  |
| 55 | 12.3 | Study on Stage 2 for GPRS-level solution |  | 301d? | 2004-10-14 A | 2005-12-08 A | 100% |  | 2004-10-14 | 2005-12-08 | 301d? |  | finish no earlier than 2005-12-08 | S2 | 2408h | 2408h |  |  | Rel-7 |  |  |  |  |  |  |  |
| 56 | 12.4 | Stage 2 Specification Phase - IMS-level |  | 200d? | 2005-09-05 A | 2006-06-09 | 80% | 40d? | 2005-09-05 | 2006-06-09 | 200d? | 545d | finish no earlier than 2006-06-09 | S2 | 1600h | 1280h |  |  | Rel-7 |  |  |  |  |  |  |  |
| 57 | 12.5 | Stage 2 Specification Phase - GPRS-level |  | 270d? | 2005-09-05 A | 2006-09-15 | 65% | 94.5d? | 2005-09-05 | 2006-09-15 | 270d? | 475d | finish no earlier than 2006-09-15 | S2 | 2160h | 1404h |  |  | Rel-7 |  |  |  |  |  |  |  |
| 58 | 10.1 | **Emergency Call Enhancements for IP& PS Based Calls – stage 3** |  | 180d | 2006-01-09 A | 2006-09-15 | 13% | 157.34d | 2006-01-09 | 2006-09-15 | 180d | 475d |  | C1 | 6684.96h | 841.62h | EMC1 | Alf Heidermark (Ericsson) | Rel-7 |  |  | CCaR |  | 1653 | alf.heidermark@ericsson.com |  |
| 59 | 10.1.2 | CT1 IMS aspects to support IMS Emergency sessions |  | 155.82d | 2006-01-09 A | 2006-09-15 | 55% | 70.12d | 2006-01-09 | 2006-09-15 | 155.82d | 475d | finish no earlier than 2006-09-15 | C1 | 1246.56h | 685.61h |  | Alf Heidermark (Ericsson) | Rel-7 |  |  | CCaR | 24.229 | 1315 | alf.heidermark@ericsson.com |  |
| 60 | 10.1.2 | CT3 IMS aspects to support IMS Emergency sessions |  | 95d | 2006-05-08 | 2006-09-15 |  |  | 2006-05-08 | 2006-09-15 | 95d | 475d | finish no earlier than 2006-09-15 | C3 | 760h |  |  | Alf Heidermark (Ericsson) | Rel-7 |  |  | CCaR | 29.163 | 1315 | alf.heidermark@ericsson.com |  |
| 61 | 10.1.5 | CT1 PS domain aspects to support IMS Emergency sessions |  | 154.9d | 2006-01-09 | 2006-09-15 |  |  | 2006-01-09 | 2006-09-15 | 154.9d | 475d | start no earlier than 2006-01-09 | C1 | 1239.2h |  |  | Alf Heidermark (Ericsson) | Rel-7 |  |  | CCaR | 24.008 | 1646 | alf.heidermark@ericsson.com |  |
| 62 | 10.1.5 | CT3 PS domain aspects to support IMS Emergency sessions |  | 95d | 2006-05-08 | 2006-09-15 |  |  | 2006-05-08 | 2006-09-15 | 95d | 475d | start no earlier than 2006-05-08 | C3 | 760h |  |  | Alf Heidermark (Ericsson) | Rel-7 |  |  | CCaR | 29.061 | 1646 | alf.heidermark@ericsson.com |  |
| 63 | 10.1.5 | CT4 PS domain aspects to support IMS Emergency sessions |  | 180d | 2006-01-09 | 2006-09-15 |  |  | 2006-01-09 | 2006-09-15 | 180d | 475d | start no earlier than 2006-01-09 | C4 | 1440h |  |  | Alf Heidermark (Ericsson) | Rel-7 |  |  | CCaR | 29.060 | 1646 | alf.heidermark@ericsson.com |  |
| 64 | 13 | **Access Class Barring and Overload Protection** |  | 650d? | 2004-03-15 A | 2006-09-08 | 41% | 385.49d? | 2004-03-15 | 2006-01-31 | 492d? | 480d |  | S2 | 13968h | 5684.06h | ACBOP | Chris Pudney, Vodafone | Rel-7 | TSG | Maurice |  | 23.898 |  |  |  |
| 65 | 13.1 | TR on Stage 2 |  | 274d? | 2004-03-15 A | 2005-03-31 A | 100% |  | 2004-03-15 | 2005-03-31 | 274d? |  | finish no earlier than 2005-03-31 | S2 | 2192h | 2192h |  |  | Rel-7 | TSG |  |  |  |  |  |  |
| 66 | 13.2 | Extra ACBOP information in GERAN |  | 650d? | 2004-03-15 | 2006-09-08 |  |  | 2004-03-15 | 2005-11-18 | 440d? | 480d | finish no earlier than 2006-09-08 | GP | 5200h |  |  |  | Rel-7 | TSG | Gert |  | 44.018 |  |  |  |
| 67 | 13.3 | Stage 3 CN aspects of ACBOP |  | 172d? | 2005-06-06 A | 2006-01-31 A | 100% |  | 2005-06-06 | 2006-01-31 | 172d? |  | start no earlier than 2005-06-06 | C1 | 1376h | 1376h |  |  | Rel-7 |  |  |  | 24.008 |  |  |  |
| 68 | 13.4 | Deleted - Potential impact on Iu interface Overload functionality | milestone | 0d? | 2004-03-15 A | 2004-03-15 A | 100% |  | 2004-03-15 | 2004-03-15 | 0d? |  | finish no earlier than 2004-03-15 | RP |  |  |  |  | Rel-7 |  |  |  | 25.413 |  |  | RP-25 |
| 69 | 13.5 | Deleted - Extra ACBOP information in RAN | milestone | 0d? | 2004-03-15 A | 2004-03-15 A | 100% |  | 2004-03-15 | 2004-03-15 | 0d? |  | finish no earlier than 2004-03-15 | RP |  |  |  |  | Rel-7 |  |  |  | 25.331 |  |  | RP-25 |
| 70 | 14 | **USSD message delivery and transfer to USIM** |  | 376d? | 2004-03-05 A | 2005-08-12 A | 100% |  | 2004-03-05 | 2005-08-12 | 376d? |  |  | S1 | 5698.4h | 5698.4h | USSD-USIM |  | Rel-7 | TSG | Michael |  | 22.090 |  |  |  |
| 71 | 14.1 | Stage 1 |  | 152d? | 2004-03-18 A | 2004-10-15 A | 100% |  | 2004-03-18 | 2004-10-15 | 152d? |  | start no earlier than 2004-03-18 | S1 | 1216h | 1216h | USSD-USIM |  | Rel-7 | TSG | Michael |  | 22.090 |  |  |  |
| 72 | 14.2 | Alignment with requirements regarding USSD usage |  | 193.3d? | 2004-03-05 A | 2005-08-12 A | 100% |  | 2004-03-05 | 2005-08-12 | 193.3d? |  | finish no earlier than 2005-08-12 | C6 | 1546.4h | 1546.4h | USSD-USIM | Christophe Dubois (Axalto) | Rel-7 | TSG |  |  |  |  | cdubois@axalto.com |  |
| 73 | 15 | **Location Services enhancements Rel-7** |  | 645d? | 2004-06-28 A | 2006-12-15 | 71% | 186.07d? | 2004-06-28 | 2006-09-15 | 580d? | 410d |  | S2 | 32909.6h | 19291.8h | LCS3 |  | Rel-7 |  | Maurice |  | 23.271 |  |  |  |
| 74 | 15.1 | Global Stage 2 for LCS3 (including IMS emergency location aspects) |  | 446d? | 2004-12-31 A | 2006-09-15 | 80% | 89.2d? | 2004-12-31 | 2006-09-15 | 446d? | 475d | finish no earlier than 2006-09-15 | S2 | 3568h | 2854.4h |  | Ben Rodilitz, SiRF | Rel-7 | TSG | Maurice |  | 23.271 |  | brodilitz@sirf.com |  |
| 75 | 15.2 | CT4 aspects for LCS |  | 66d? | 2006-01-02 A | 2006-04-03 | 60% | 26.4d? | 2006-01-02 | 2006-04-03 | 66d? | 509d | start no earlier than 2006-01-01 | C4 | 528h | 316.8h | LCS3-UEPos-LBS |  | Rel-7 | TSG |  |  |  |  |  |  |

Notes:
- 67: NEW - inserted on 2/9/2004
- 74: Approved SA#27. Appropriate place forEmergency work to be found
- 75: CR approved in CT4#30

| ID | WBS | Task | Type | Duration | Start | Finish | Complete | Remaining | Baseline start | Baseline finish | Baseline duration | Total slack | Constraint | Resources | Work | Actual work | Text1 | Text6 | Text7 | Text8 | Text5 | Text12 |
| --- | --- | --- | --- | --- | --- | --- | --- | --- | --- | --- | --- | --- | --- | --- | --- | --- | --- | --- | --- | --- | --- | --- |
| 76 | 15.3 | **LCS for 3GPP Interworking WLAN** |  | 630d? | 2004-06-28 A | 2006-11-24 | 99% | 0d? | 2004-06-28 | 2006-09-15 | 580d? | 0d |  | S1 | 9141.6h | 4200h | LCS3-IWLAN | Rel-7 | TSG | Michael |  |  |
| 77 | 15.3.1 | FS on 3GPP system to WLAN Interworking with LCS |  | 512.7d? | 2004-06-28 A | 2006-06-30 A | 100% |  | 2004-06-28 | 2006-06-30 | 512.7d? |  | finish no earlier than 2005-09-29 | S1 | 4101.6h | 4101.6h |  | Rel-7 |  |  |  |  |
| 78 | 15.3.2 | Deleted - covered by 320017 - Study of work on an LCS architecture for I-WLAN. | milestone | 0d? | 2006-11-24 A | 2006-11-24 A | 100% |  | 2006-01-16 | 2006-09-15 | 175d? |  | start no earlier than 2006-11-24 | S2 |  |  |  | Rel-7 |  | Maurice | dhshim@lge.com ; phede@lge.com |  |
| 79 | 15.4 | **UE positioning Rel-7** |  | 588d? | 2004-09-15 A | 2006-12-15 | 85% | 88.2d? | 2004-09-15 | 2006-06-15 | 456d? | 410d |  | RP | 9408h | 6709.24h | LCS3-UEpos | Rel-7 | TSG | Cesar |  |  |
| 80 | 15.4.1 | Inclusion of Uplink TDOA UE positioning method in the UTRAN specifications |  | 588d? | 2004-09-15 A | 2006-12-15 | 85% | 88.2d? | 2004-09-15 | 2006-06-15 | 456d? | 410d | finish no earlier than 2006-12-15 | R2 | 4704h | 3998.4h | LCS3-UEPos-UTDOA | Rel-7 | TSG | MCC_RAN | rlgross@trueposition.com |  |
| 81 | 15.5 | UE positioning - Velocity |  | 198d? | 2005-03-15 A | 2005-12-15 | 75% | 49.5d? | 2005-03-15 | 2005-06-14 | 66d? | 671d | finish no earlier than 2005-12-15 | R2 | 1584h | 1188h | LCS3-UEPos-Velocity | Rel-7 | TSG | MCC_RAN | BRodilitz@SiRF.com |  |
| 82 | 15.6 | LCS Enhancements Related to Location-Based Services |  | 440d? | 2005-01-03 A | 2006-09-08 | 10% | 396d? | 2005-01-03 | 2006-06-30 | 390d? | 480d | finish no earlier than 2006-09-08 | GP | 3520h | 352h | LCS3-LBS | Rel-7 | TSG | Paolo | kjudge@sirf.com |  |
| 83 | 15.7 | Deleted - RAN2 aspects for LBS | milestone | 0d? | 2005-06-15 A | 2005-06-15 A | 100% |  | 2005-06-15 | 2005-06-15 | 0d? |  | start no earlier than 2005-06-15 | R2 |  |  | LCS3-UEPos-LBS | Rel-7 | TSG | MCC_RAN | BRodilitz@SiRF.com | RP-31 |
| 84 | 16 | **Advanced Global Navigation Satellite System (A-GNSS) concept** |  | 840d? | 2004-06-28 A | 2007-09-15 | 30% | 591.95d? | 2004-06-28 | 2007-09-15 | 840d? | 215d |  | S1 | 18897.6h | 3746.4h | LCS3-AGNSS | Rel-7 | TSG | Michael | Michel.monnerat@space.alcatel.fr |  |
| 85 | 16.1 | Towards A-GNSS Concept |  | 459d? | 2004-08-27 A | 2006-05-31 | 45% | 252.45d? | 2004-08-27 | 2006-05-31 | 459d? | 467d | finish no earlier than 2005-09-29 | S1 | 3672h | 1652.4h | GNSS | Rel-7 | TSG | Paolo | richard.couty@space.alcatel.fr |  |
| 86 | 16.2 | Support for GNSS in GERAN |  | 606.2d? | 2004-06-28 A | 2006-11-17 | 25% | 454.65d? | 2004-06-28 | 2006-11-17 | 606.2d? | 345d | finish no earlier than 2006-11-17 | GP | 4849.6h | 1212.4h | AGNSS-GP | Rel-7 | TSG | Paolo | richard.couty@space.alcatel.fr |  |
| 87 | 16.3 | Global Navigation Satellite System (GNSS) in UTRAN |  | 457d? | 2005-12-15 A | 2007-09-15 | 20% | 365.6d? | 2005-12-15 | 2007-09-15 | 457d? | 215d | finish no earlier than 2007-09-15 | R2 | 3656h | 731.2h | LCS3-GNSS-UTRAN | Rel-7 |  | MCC_RAN | alain.abinakhoul@francetelecom.com |  |
| 88 | 17 | A-GPS Minimum Performance |  | 261d? | 2006-04-28 A | 2007-04-27 | 20% | 208.8d? | 2006-04-28 | 2007-04-27 | 261d? | 315d | finish no earlier than 2007-04-27 | G1; G3 | 2088h | 417.6h | GAGR | Rel-7 |  | Paolo | richard.catmur@spirentcom.com |  |
| 89 | 18 | **Combinational Services** |  | 296d? | 2005-01-17 A | 2006-03-06 | 98% | 5.06d? | 2005-01-17 | 2006-03-06 | 296d? | 614d |  | S1 | 7544h | 7415.16h | CSICS | Rel-7 | TSG | Michael | Robert.Frank@teliasonera.com |  |
| 90 | 18.1 | Stage 1 for CSICS |  | 104d? | 2005-01-17 A | 2005-06-09 A | 100% |  | 2005-01-17 | 2005-06-09 | 104d? |  | start no earlier than 2005-01-17 | S1 | 832h | 832h |  | Rel-7 | TSG |  |  |  |
| 91 | 18.2 | Stage 2 for CSICS |  | 130d? | 2005-01-17 A | 2005-07-15 A | 100% |  | 2005-01-17 | 2005-07-15 | 130d? |  | start no earlier than 2005-01-17 | S2 | 1040h | 1040h |  | Rel-7 |  |  |  |  |
| 92 | 18.3 | Stage 3 for CSICS CN aspects |  | 221d? | 2005-05-02 A | 2006-03-06 | 95% | 11.05d? | 2005-05-02 | 2006-03-06 | 221d? | 614d | finish no earlier than 2006-03-06 | C1 | 1768h | 1679.6h |  | Rel-7 | TSG | Andrijana |  |  |
| 93 | 18.4 | Stage 3 for codec aspects |  | 192d? | 2005-03-15 A | 2005-12-07 A | 100% |  | 2005-03-15 | 2005-12-07 | 192d? |  | finish no earlier than 2005-12-07 | S4 | 1536h | 1536h | CSICS-Codec | Rel-7 | TSG | Paolo | Per.Frojdh@ericsson.com |  |
| 94 | 19 | **System enhancements for fixed broadband access to IMS** |  | 844d? | 2003-11-05 A | 2007-01-29 | 61% | 332.35d? | 2003-11-05 | 2007-01-29 | 844d? | 379d |  | S2 | 39465.6h | 18934.4h | FBI | Rel-7 | TSG | Maurice |  |  |
| 95 | 19.1 | **TISPAN Rel 1 related aspects** |  | 748d? | 2003-11-05 A | 2006-09-15 | 76% | 180.58d? | 2003-11-05 | 2006-03-08 | 611d? | 475d |  | S2 | 25816h | 14849.1h |  | Rel-7 |  |  |  |  |
| 96 | 19.1.1 | Stage 2 of FBI for TISPAN R1 |  | 365d? | 2004-10-14 A | 2006-03-08 A | 100% |  | 2004-10-14 | 2006-03-08 | 365d? |  | start no earlier than 2004-10-14 | S2 | 2920h | 2920h |  | Rel-7 |  | Maurice |  |  |
| 97 | 19.1.2 | **Protocol impact of FBI for TISPAN R1** |  | 748d? | 2003-11-05 A | 2006-09-15 | 71% | 213.52d? | 2003-11-05 | 2005-11-30 | 541d? | 475d |  | C1 | 15968h | 11409.9h |  | Rel-7 | TSG | Andrijana |  |  |
| 98 | 19.1.2.1 | CT1 aspects of FBI for TISPAN R1 |  | 347d? | 2004-08-03 A | 2005-11-30 | 90% | 34.7d? | 2004-08-03 | 2005-11-30 | 347d? | 682d | finish no earlier than 2005-03-03 | C1 | 2776h | 2498.4h |  | Rel-7 | TSG | Andrijana |  |  |
| 99 | 19.1.2.2 | CT3 aspects of FBI for TISPAN R1 |  | 748d? | 2003-11-05 A | 2006-09-15 | 96% | 29.92d? | 2003-11-05 | 2005-03-03 | 347d? | 475d | finish no earlier than 2006-09-15 | C3 | 5984h | 5744.64h |  | Rel-7 | TSG | Andrijana |  |  |
| 100 | 19.1.2.3 | CT4 aspects of FBI for TISPAN R1 |  | 347d? | 2003-11-05 | 2005-03-03 |  |  | 2003-11-05 | 2005-03-03 | 347d? | 876d | finish no earlier than 2005-03-03 | C4 | 2776h |  |  | Rel-7 | TSG | Andrijana |  |  |
| 101 | 19.1.3 | Security Enhancements for FBI |  | 118d? | 2005-06-28 A | 2005-12-08 | 55% | 53.1d? | 2005-06-28 | 2005-12-08 | 118d? | 591d | start no earlier than 2005-06-28 | S3 | 944h | 519.2h | FBI-ISE | Rel-7 |  | Mike | Bengt.Sahlin@ericsson.com |  |

Notes:
- 76: Text3: 22.935 / Text4: Mike Loushine, (Telcordia)
- 77: DAB - Should be SA1 / Text3: 22.935
- 78: Changed from "stage 2" to "study" between SA#31 and SA#32. Updated WID approved SA#32 / Text3: 23.837 / Text4: Donghee Shim (LG Electronics Inc.); Patrice HÉDÉ (LG Electronics Mobilecomm France)
- 80: Text3: TS25.305, TS25.453 / Text4: Robert Gross, TruePosition
- 81: Text3: 25.305, 25.331, 25.410, 25.413, 25.453 / Text4: Ben Rodilitz
- 82: Linked SP-040682 Close at GP#31 ? / Text3: 43.059, 44.031, 48.008, 49.031 / Text4: Kevin Judge, SiRF Technologies
- 83: Text3: 25.305, 25.331, 25.410, 25.413, 25.453 / Text4: Ben Rodilitz
- 84: Text4: Michel MONNERAT
- 85: Text4: Richard Couty, ALCATEL SA
- 86: Started / Text4: Richard Couty, ALCATEL SA
- 87: Text3: TS 25.305,TS 25.331,TS 25.306,TS 25.413,TS 25.423,TS 25.433,TS 25.453,TS 25.171,TS 34.171 / Text4: Alain Abinakhoul, France Telecom
- 88: Text3: 45.005, 51.010 / Text4: Richard Catmur, Spirent Communications
- 89: Text4: Robert Frank, TeliaSonera
- 90: Text3: 22.279
- 91: Text3: 23.279
- 92: Text3: New TS 24.279, 24.229, 24.008 / Text4: Peter Dawes (Vodafone)
- 93: Started / Text3: TS 26.141, 26.235, 26.236 / Text4: Per Fröjdh, Ericsson
- 97: Text3: new TR 24.819, 24.229, 29.229, 29.163, 29.209 / Text4: Peter Leis (Siemens)
- 98: Text3: new TR 24.819, 24.229, 29.229, 29.163, 29.209 / Text4: Siemens
- 99: Text3: new TR, 29.229, 29.163 / Text4: Siemens
- 100: Text3: 29.209 / Text4: Siemens
- 101: Duplicated entry ("ACCSEC2", "Access Security Enhancements", SP-040865) deleted by A.Sultan / Text3: 33.102, 43.020 / Text4: Bengt Sahlin, Ericsson

| ID | WBS | Task | Type | Duration | Start | Finish | Complete | Remaining | Baseline start | Baseline finish | Baseline duration | Total slack | Constraint | Resources | Work | Actual work | Text1 | Text6 | Text3 | Text4 | Text5 | Text8 | Text7 |
| --- | --- | --- | --- | --- | --- | --- | --- | --- | --- | --- | --- | --- | --- | --- | --- | --- | --- | --- | --- | --- | --- | --- | --- |
| 102 | 19.2 | **PacketCable Related aspects** |  | 228d? | 2006-02-01 A | 2006-12-15 | 41% | 133.7d? | 2006-02-01 | 2006-12-15 | 228d? | 410d |  | S2 | 6184h | 1872.8h | FBI-PCBL | Rel-7 |  |  |  |  |  |
| 103 | 19.2.1 | Stage 2 of FBI for PacketCable |  | 228d? | 2006-02-01 A | 2006-12-15 | 30% | 159.6d? | 2006-02-01 | 2006-12-15 | 228d? | 410d | finish no earlier than 2006-12-15 | S2 | 1824h | 547.2h |  | Rel-7 |  |  |  |  |  |
| 104 | 19.2.2 | Protocol impact of FBI for PacketCable |  | 152d? | 2006-05-01 A | 2006-11-28 | 5% | 144.4d? | 2006-05-01 | 2006-11-28 | 152d? | 423d | start no earlier than 2006-05-01 | C1 | 1216h | 60.8h |  | Rel-7 |  |  |  |  |  |
| 105 | 19.2.3 | SA5 Charging aspects of FBI for PacketCable |  | 186d? | 2006-03-31 A | 2006-12-15 | 85% | 27.9d? | 2006-03-31 | 2006-12-15 | 186d? | 410d | finish no earlier than 2006-12-15 | S5 | 1488h | 1264.8h | FBI-PCBL-CH | Rel-7 | 32.240, 32.260, 32.298, 32.299 | CableLabs | Bernie McKibben | Adrian |  |
| 106 | 19.3 | **TISPAN Rel 2 related aspects** |  | 173d? | 2006-06-01 | 2007-01-29 |  |  | 2006-06-01 | 2007-01-29 | 173d? | 379d |  | S2 | 3816h |  | FBI-TISP2 | Rel-7 |  |  |  |  |  |
| 107 | 19.3.1 | Stage 2 of FBI for TISPAN R2 |  | 152d? | 2006-06-30 | 2007-01-29 |  |  | 2006-06-30 | 2007-01-29 | 152d? | 379d | start no earlier than 2006-06-30 | S2 | 1216h |  |  | Rel-7 |  |  |  |  |  |
| 108 | 19.3.2 | Protocol impact of FBI for TISPAN R2 |  | 152d? | 2006-06-01 | 2006-12-29 |  |  | 2006-06-01 | 2006-12-29 | 152d? | 400d | start no earlier than 2006-06-01 | C1 | 1216h |  |  | Rel-7 |  |  |  |  |  |
| 109 | 20 | Access Security Enhancements |  | 195d? | 2005-01-03 A | 2005-09-30 | 75% | 48.75d? | 2005-01-03 | 2005-09-30 | 195d? | 725d | finish no earlier than 2005-09-30 | S3 | 1560h | 1170h | ACCSEC2 | Rel-7 | 33.102, 43.020 | Bengt Sahlin, Ericsson | Bengt.Sahlin@ericsson.com | Michael | TSG |
| 110 | 21 | **Mp (MRFC - MRFP) interface** |  | 290d? | 2006-02-13 A | 2007-03-23 | 27% | 211.93d? | 2006-02-13 | 2007-03-23 | 290d | 340d |  | C4 | 7048h | 1897.35h | Mp | Rel-7 |  | Emmanuel Gay (Orange) |  | Kimmo |  |
| 111 | 21.1 | CT1 aspects of Mp | milestone | 0d | 2006-02-13 | 2006-02-13 |  |  | 2006-02-13 | 2006-02-13 | 0d | 630d | finish no earlier than 2006-02-13 | C1 |  |  |  | Rel-7 | 24.229 | Orange |  |  |  |
| 112 | 21.2 | CT3 aspects of Mp |  | 160d | 2006-02-13 | 2006-09-22 |  |  | 2006-02-13 | 2006-09-22 | 160d | 470d | start no earlier than 2006-02-13 | C3 | 1280h |  |  | Rel-7 | 29.162 | Orange |  |  |  |
| 113 | 21.3 | Procedures description |  | 141d? | 2006-06-02 A | 2006-12-15 | 10% | 126.9d? |  |  |  | 410d | finish no earlier than 2006-12-15 | C4 | 1128h | 112.8h |  | Rel-7 | 23.333 | Huawei |  | Kimmo |  |
| 114 | 21.4 | Stage 3 |  | 290d | 2006-02-13 A | 2007-03-23 | 50% | 145d | 2006-02-13 | 2007-03-23 | 290d | 340d | finish no earlier than 2007-03-23 | C4 | 2320h | 1160h |  | Rel-7 | 29.333 | Orange |  | Kimmo |  |
| 115 | 22 | IMS Stage 3 IETF Protocol alignment |  | 461d? | 2004-12-10 A | 2006-09-15 | 45% | 253.55d? | 2004-12-10 | 2006-09-15 | 461d? | 390d | finish no earlier than 2006-09-15 | C1 | 3688h | 1659.6h | IMSProtoc | Rel-7 | TR 24.930 |  |  |  |  |
| 116 | 23 | **Support of SMS and MMS over generic 3GPP IP access** |  | 502d? | 2004-10-14 A | 2006-09-15 | 60% | 199.03d? | 2004-10-14 | 2006-09-15 | 502d? | 475d |  | S2 | 15936h | 7967.6h | SMSIP | Rel-7 | TR 23.abc, TS 23.abc | Wenlin Zhang (Huawei) | zhangwenlin@huawei.com | Maurice | TSG |
| 117 | 23.1 | FS on SMSIP |  | 173d? | 2004-10-14 A | 2005-06-13 A | 100% |  | 2004-10-14 | 2005-06-13 | 173d? |  | start no earlier than 2004-10-14 | S2 | 1384h | 1384h |  | Rel-7 | 23.804 |  |  |  |  |
| 118 | 23.2 | Stage 2 for SMSIP |  | 333d? | 2005-06-08 A | 2006-09-15 | 70% | 99.9d? | 2005-06-08 | 2006-09-15 | 333d? | 475d | finish no earlier than 2006-09-15 | S2 | 2664h | 1864.8h |  | Rel-7 | 23.204 |  |  |  |  |
| 119 | 23.3 | **Stage 3 for SMSIP** |  | 328d? | 2005-06-08 A | 2006-09-08 | 45% | 180.4d? | 2005-06-08 | 2006-09-08 | 328d? | 480d |  | C4 | 7872h | 3542.4h |  | Rel-7 |  |  |  |  |  |
| 120 | 23.3.1 | CT1 aspects for SMSIP |  | 328d? | 2005-06-08 A | 2006-09-08 | 40% | 196.8d? | 2005-06-08 | 2006-09-08 | 328d? | 480d | start no earlier than 2005-06-08 | C1 | 2624h | 1049.6h |  | Rel-7 |  |  |  |  |  |
| 121 | 23.3.2 | CT4 aspects for SMSIP |  | 328d? | 2005-06-08 A | 2006-09-08 | 50% | 164d? | 2005-06-08 | 2006-09-08 | 328d? | 480d | start no earlier than 2005-06-08 | C4 | 2624h | 1312h |  | Rel-7 |  |  |  |  |  |
| 122 | 24 | **Evolution of Policy Control and Charging** |  | 567d? | 2004-10-14 A | 2006-12-15 | 45% | 313.77d? | 2004-10-14 | 2006-12-15 | 567d? | 410d |  | S2 | 19608h | 8241.35h | PCC | Rel-7 |  |  |  | Maurice | TSG |
| 123 | 24.1 | TR for PCC |  | 315d? | 2004-10-14 A | 2005-12-29 A | 100% |  | 2004-10-14 | 2005-12-29 | 315d? |  | finish no earlier than 2005-12-28 | S2 | 2520h | 2520h |  | Rel-7 |  |  |  |  |  |
| 124 | 24.2 | Stage 2 for PCC |  | 315d? | 2005-07-04 A | 2006-09-15 | 70% | 94.5d? | 2005-07-04 | 2006-09-15 | 315d? | 475d | finish no earlier than 2006-09-15 | S2 | 2520h | 1764h |  | Rel-7 | 23.203 |  |  |  |  |
| 125 | 24.3 | Evolution of policy control and flow based bearer level charging |  | 116d? | 2006-06-30 | 2006-12-08 |  |  | 2006-06-30 | 2006-12-08 | 116d? | 415d | start no earlier than 2006-06-30 | S2 | 928h |  |  | Rel-7 | 23.207, 23.125, 23.002, 23.228 | Balazs Bertenyi (Nokia) | balazs.bertenyi@nokia.com |  |  |
| 126 | 24.4 | SA5 Charging aspects of PCC |  | 186d? | 2006-03-31 | 2006-12-15 |  |  | 2006-03-31 | 2006-12-15 | 186d? | 410d | finish no earlier than 2006-12-15 | S5 | 1488h |  | PCC-CH | Rel-7 | 32.250, 32.251, 32.298, 32.299 | Orange | alain.bibas@orange-ft.com | Adrian |  |
| 127 | 24.5 | Gx reference point for Policy and Charging Control |  | 260d? | 2005-12-02 A | 2006-11-30 | 40% | 156d? | 2005-12-02 | 2006-11-30 | 260d? | 421d | start no earlier than 2005-12-02 | C3 | 2080h | 832h |  | Rel-7 | 29.210, 29.207, 29.208 | Thomas Belling (Siemens) | thomas.belling@siemens.com | Seung Don |  |

Notes:
- 105: 03/2006 SA#31 WID approved
- 109: WID approved SA#26. Record created after SA#27. It is about improved GERAN security
- 114: indication in CT4#31 50%
- 115: TR 24.930: Signalling flows for the session setup in the IM CN subsystem based on Session Initiation Protocol (SIP)
- 116: Revised at SP#29
- 125: Approved at SP#29. 23.125 will be discontinued from Release 7.
- 126: 03/2006 SA#31 WID approved
- 127: Approved at CP#30, Revised at CP#31

| ID | WBS | Task | Type | Duration | Start | Finish | Complete | Remaining | Baseline start | Baseline finish | Baseline duration | Total slack | Constraint | Resources | Work | Actual work | Text1 | Text4 | Text5 | Text6 | Text8 | Text7 |
| --- | --- | --- | --- | --- | --- | --- | --- | --- | --- | --- | --- | --- | --- | --- | --- | --- | --- | --- | --- | --- | --- | --- |
| 128 | 24.6 | **Rx reference point for PCC CT3 aspects** |  | 260d? | 2005-12-02 A | 2006-11-30 | 20% | 208.36d? | 2005-12-02 | 2006-11-30 | 260d? | 421d |  | C3 | 5536h | 1099.51h | PCC-Rx | Javier Pastor (Ericsson) | j.javier.pastor@ericsson.com | Rel-7 | Seung Don |  |
| 129 | 24.6.1 | PCC-Rx CT3 aspects |  | 260d? | 2005-12-02 A | 2006-11-30 | 33% | 174.2d? | 2005-12-02 | 2006-11-30 | 260d? | 421d | start no earlier than 2005-12-02 | C3 | 2080h | 686.4h |  | Javier Pastor (Ericsson) | j.javier.pastor@ericsson.com | Rel-7 | Seung Don |  |
| 130 | 24.6.2 | PCC-Rx CT1 aspects |  | 172d? | 2005-12-02 | 2006-09-29 |  |  | 2005-12-02 | 2006-09-29 | 172d? | 465d | start no earlier than 2005-12-02 | C1 | 1376h |  |  |  |  | Rel-7 |  |  |
| 131 | 25 | Video Codec Performance Requirements |  | 504d? | 2005-01-03 A | 2006-12-07 | 55% | 226.8d? | 2005-01-03 | 2006-12-07 | 504d? | 331d | finish no earlier than 2006-12-07 | S4 | 4032h | 2217.6h | VICPer | Juergen Pandel (Siemens AG) | juergen.pandel@siemens.com | Rel-7 | Paolo | TSG |
| 132 | 26 | DIAMETER on the GGSN Gi interface |  | 531d? | 2004-09-10 A | 2006-09-22 | 40% | 318.6d? | 2004-09-10 | 2006-09-22 | 531d? | 470d | finish no earlier than 2006-09-22 | C3 | 4248h | 1699.2h | DIAMGi |  |  | Rel-7 | Seung Don | TSG |
| 133 | 27 | DIAMETER on the PDG Wi inteface |  | 531d? | 2004-09-10 A | 2006-09-22 | 40% | 318.6d? | 2004-09-10 | 2006-09-22 | 531d? | 470d | finish no earlier than 2006-09-22 | C3 | 4248h | 1699.2h | DIAMWi |  |  | Rel-7 | Seung Don | TSG |
| 134 | 28 | **CAMEL Trunk Triggers** |  | 251d? | 2004-12-17 A | 2005-12-05 A | 100% |  | 2004-12-17 | 2005-12-05 | 251d? |  |  | S1 | 6024h | 6024h | TTCAMEL | Amar Deol, Nortel Networks | deola@nortelnetworks.com | Rel-7 | Michael | TSG |
| 135 | 28.1 | Stage 1 for CAMEL Trunk Triggers |  | 251d? | 2004-12-17 A | 2005-12-05 A | 100% |  | 2004-12-17 | 2005-12-05 | 251d? |  |  | S1 | 2008h | 2008h |  | Amar Deol, Nortel Networks | deola@nortelnetworks.com | Rel-7 | Michael | TSG |
| 136 | 28.2 | CAMEL Trunk Originated Trigger Detection Points |  | 251d? | 2004-12-17 A | 2005-12-05 A | 100% |  | 2004-12-17 | 2005-12-05 | 251d? |  | start no earlier than 2004-12-17 | C4 | 2008h | 2008h | CamelR7 | David Hutton, Nortel Networks | dhutton@nortel.com | Rel-7 | Kimmo | TSG |
| 137 | 29 | MS Antenna Performance Evaluation Method and Requirements |  | 471d? | 2005-01-28 A | 2006-11-17 | 75% | 117.75d? | 2005-01-28 | 2006-06-30 | 371d? | 430d | finish no earlier than 2006-11-17 | G1 | 3768h | 2826h | APEMR | Ulf.Tegth (TeliaSonera) | Ulf.Tegth@teliasonera.com | Rel-7 | Paolo | TSG |
| 138 | 30 | **Lower 700 MHz Inclusion in the GERAN Specifications** |  | 390d? | 2005-01-03 A | 2006-06-30 | 99% | 0d? | 2005-01-03 | 2006-06-30 | 390d? | 0d |  | GP | 7632h | 5105.6h | GSM710 | Dave Cotton (UTC) | dcotton@mtview.union-tel.com | Rel-7 | Paolo | TSG |
| 139 | 30.1 | Inclusion of the 698 – 746 MHz band into GERAN core specifications |  | 129d? | 2005-01-03 A | 2005-06-30 A | 100% |  | 2005-01-03 | 2005-06-30 | 129d? |  | finish no earlier than 2005-06-30 | G1 | 1032h | 1032h | GSM710-core |  |  | Rel-7 | Paolo |  |
| 140 | 30.2 | G1 aspects of GSM710 |  | 217.5d? | 2005-08-31 A | 2006-06-30 A | 100% |  | 2005-08-31 | 2006-06-30 | 217.5d? |  | finish no earlier than 2006-06-30 | G1 | 1740h | 1740h | GSM-710-test |  |  | Rel-7 | Paolo |  |
| 141 | 30.3 | G3 aspects of GSM710 |  | 217.5d? | 2005-08-31 A | 2006-06-30 A | 100% |  | 2005-08-31 | 2006-06-30 | 217.5d? |  | finish no earlier than 2006-06-30 | G3 | 1740h | 1740h | GSM-710-test |  |  | Rel-7 | Stoyan |  |
| 142 | 31 | **Enhancements of VGCS for public authority officials** |  | 536d? | 2004-08-27 A | 2006-09-15 | 90% | 53.03d? | 2004-08-27 | 2006-09-15 | 536d? | 475d |  | S1 | 20320h | 14569.9h | EVGCS | Siemens |  | Rel-7 | Andrijana | TSG |
| 143 | 31.1 | Stage 1 | milestone | 0d? | 2004-08-27 A | 2004-08-27 A | 100% |  | 2004-08-27 | 2004-08-27 | 0d? |  | finish no earlier than 2004-08-27 | S1 |  |  |  | Joerg Swetina (Siemens AG) | joerg.swetina@SIEMENS.COM | Rel-7 | Michael | TSG |
| 144 | 31.2 | **Architecture and protocol aspects** |  | 536d? | 2004-08-27 A | 2006-09-15 | 93% | 37.52d? | 2004-08-27 | 2006-09-15 | 536d? | 475d |  | C1 | 11784h | 10959.1h |  | Robert Zaus (Siemens) |  | Rel-7 |  |  |
| 145 | 31.2.1 | CT1 aspects of EVGCS |  | 536d? | 2004-08-27 A | 2006-09-15 | 93% | 37.52d? | 2004-08-27 | 2006-09-15 | 536d? | 475d | finish no earlier than 2006-09-15 | C1 | 4288h | 3987.84h |  | Siemens |  | Rel-7 |  |  |
| 146 | 31.2.2 | CT4 aspects of EVGCS |  | 401d? | 2004-08-27 A | 2006-03-10 | 93% | 28.07d? | 2004-08-27 | 2006-03-10 | 401d? | 610d | finish no earlier than 2006-03-10 | C4 | 3208h | 2983.44h |  | Siemens |  | Rel-7 |  |  |
| 147 | 31.3 | GERAN2 aspects |  | 531d? | 2004-08-27 A | 2006-09-08 | 85% | 79.65d? | 2004-08-27 | 2006-06-30 | 481d? | 480d | finish no earlier than 2006-09-08 | G2 | 4248h | 3610.8h |  | Ken Isaacs (Siemens) | kenneth.isaacs@roke.co.uk | Rel-7 | Gert | TSG |
| 148 | 32 | **Improvements of VGCS for parallel use of services** |  | 381d? | 2005-03-15 A | 2006-08-29 | 33% | 254.21d? | 2005-03-15 | 2006-08-29 | 381d? | 488d |  | S1 | 8830.16h | 1936h | IVGCS |  |  | Rel-7 |  |  |
| 149 | 32.1 | Service Requirements for VGCS improvements |  | 62d? | 2005-03-15 A | 2005-06-08 A | 100% |  | 2005-03-15 | 2005-06-08 | 62d? |  | finish no earlier than 2005-06-08 | S1 | 496h | 496h |  | Kurt Bischinger (T-Mobile) | kurt.bischinger@t-mobile.at | Rel-7 | Michael | TSG |
| 150 | 32.2 | Stage 2 modifications for VGCS improvements |  | 142d? | 2005-12-01 A | 2006-06-16 | 32% | 97d? | 2005-12-01 | 2006-06-16 | 142d? | 540d | start no earlier than 2005-12-01 | C1 | 1136h | 360h |  | Kurt Bischinger (T-Mobile) | kurt.bischinger@t-mobile.at | Rel-7 |  | TSG |
| 151 | 32.3 | **Protocol aspects** |  | 194d? | 2005-12-01 A | 2006-08-29 | 23% | 149d? | 2005-12-01 | 2006-08-29 | 194d? | 488d |  | C1 | 4656h | 1080h |  | Dieter Jacobsohn (T-Mobile) |  | Rel-7 |  |  |
| 152 | 32.3.1 | CT1 aspects of IVGCS |  | 194d? | 2005-12-01 A | 2006-08-29 | 23% | 149d? | 2005-12-01 | 2006-08-29 | 194d? | 488d | start no earlier than 2005-12-01 | C1 | 1552h | 360h |  | T-Mobile |  | Rel-7 |  |  |
| 153 | 32.3.2 | CT4 aspects of IVGCS |  | 194d? | 2005-12-01 A | 2006-08-29 | 23% | 149d? | 2005-12-01 | 2006-08-29 | 194d? | 488d | start no earlier than 2005-12-01 | C4 | 1552h | 360h |  | T-mobile |  | Rel-7 |  |  |

Notes:
- 128: Approved at CP#30, Revised at CP#31 / Text3: 29.209, 29.211, 24.229
- 129: Approved at CP#30, Revised at CP#31 / Text3: 29.209, 29.211, 24.229
- 131: Text3: 26.234, 26.235, 26.346, 26.140
- 132: 13/12/2005 08:00 / Text3: 29.061
- 133: 13/12/2005 08:00 / Text3: 29.161
- 136: Not started
- 137: Started / Text3: 25.9xx, 45.005
- 138: Started / Text3: 24.008, 43.022, 44.018, 44.118, 45, 001, 45.005, 51.010, 51.021
- 139: Completed / Text3: 24.008, 43.022, 44.018, 44.118, 45, 001, 45.005,
- 140: Text3: 51.021
- 141: Text3: 51.010
- 142: Text3: 43.068, 44.068, 24.008, 29.002
- 143: Text3: 42.068, 43.068
- 144: Text3: 43.068, 44.068
- 145: Text3: 43.068, 44.068, 24.008
- 146: Text3: 29.002
- 149: "completeed" as from Chris S' e-mail / Text3: 42.068
- 150: Text3: 43.068
- 151: Previous name (before CT32) was Architecture and protocol aspects / Text3: 44.068
- 152: Text3: 43.068, 44.068, 24.008
- 153: Text3: 29.002

| ID | WBS | Task | Type | Duration | Start | Finish | Complete | Remaining | Baseline start | Baseline finish | Baseline duration | Total slack | Constraint | Resources | Work | Actual work | Text1 | Text4 | Text5 | Text6 | Text7 | Text8 | Text3 | Text10 |
| --- | --- | --- | --- | --- | --- | --- | --- | --- | --- | --- | --- | --- | --- | --- | --- | --- | --- | --- | --- | --- | --- | --- | --- | --- |
| 154 | 33 | **OSA Rel-7** |  | 449d? | 2005-03-15 A | 2006-12-01 | 70% | 133.1d? | 2005-03-15 | 2006-12-01 | 449d? | 420d |  | S1 | 11576h | 7364h | OSA7 | Eamonn Murray (AePONA) | eamonn.murray@aepona.com | Rel-7 | TSG | Michael |  |  |
| 155 | 33.1 | Service Requirements for OSA Service Broker |  | 62d? | 2005-03-15 A | 2005-06-08 A | 100% |  | 2005-03-15 | 2005-06-08 | 62d? |  | finish no earlier than 2005-06-08 | S1 | 496h | 496h | OSA7-SB | Eamonn Murray (AePONA) | eamonn.murray@aepona.com | Rel-7 | TSG | Michael | 22.127 |  |
| 156 | 33.2 | Stage 2 OSA API Service Brokering |  | 156d? | 2006-04-28 A | 2006-12-01 A | 100% |  | 2006-04-28 | 2006-12-01 | 156d? |  |  | C5 | 1248h | 1248h | OSA7-SB | Eamonn Murray (AePONA) | eamonn.murray@aepona.com | Rel-7 | TSG | Adrian | 23.198 |  |
| 157 | 33.3 | Stage 3 OSA API Service Brokering |  | 156d? | 2006-04-28 A | 2006-12-01 | 60% | 62.4d? | 2006-04-28 | 2006-12-01 | 156d? | 335d | finish no earlier than 2006-12-01 | C5 | 1248h | 748.8h | OSA7-SB | Eamonn Murray (AePONA) |  | Rel-7 |  |  | 29.198-16 |  |
| 158 | 33.4 | **OSA Stage 2/3 enhancements** |  | 156d? | 2006-04-28 A | 2006-12-01 | 60% | 62.4d? | 2006-04-28 | 2006-12-01 | 156d? | 420d |  | C5 | 4992h | 2344h | OSA7 | Damian O’Neill (AePONA) | damian.oneill@aepona.com | Rel-7 |  | Adrian | 23.198, 29.198,29.998,29.199 |  |
| 159 | 33.4.1 | Parlay X Message Broadcast |  | 156d? | 2006-04-28 A | 2006-12-01 | 60% | 62.4d? | 2006-04-28 | 2006-12-01 | 156d? | 420d | finish no earlier than 2006-12-01 | C5 | 1248h | 748.8h |  | Mr. JeongHwan Kim (ETRI) |  | Rel-7 |  |  | 29.199-15 |  |
| 160 | 33.4.2 | Parlay X Geocoding and Mapping |  | 156d? | 2006-04-28 A | 2006-12-01 | 60% | 62.4d? | 2006-04-28 | 2006-12-01 | 156d? | 420d | finish no earlier than 2006-12-01 | C5 | 1248h | 748.8h |  | Mrs. Hyunkyung Yoo (ETRI) |  | Rel-7 |  |  | 29.199-16 |  |
| 161 | 33.4.3 | Parlay X Application driven QoS |  | 156d? | 2006-04-28 A | 2006-12-01 | 60% | 62.4d? | 2006-04-28 | 2006-12-01 | 156d? | 420d | finish no earlier than 2006-12-01 | C5 | 1248h | 748.8h |  | Mr. Darren Gunning |  | Rel-7 |  |  | 29.199-17 |  |
| 162 | 34 | Dynamic and interactive multimedia scenes |  | 453d? | 2005-03-15 A | 2006-12-07 | 40% | 271.8d? | 2005-03-15 | 2006-12-07 | 453d? | 331d | finish no earlier than 2006-12-07 | S4 | 3624h | 1449.6h | DIMS | Gaëlle MARTIN-COCHER (Streamezzo) | gaelle.martin-cocher@streamezzo.com | Rel-7 | TSG | Paolo | 26.234, 23.346, 26.140, 26.244 |  |
| 163 | 35 | Liberty Alliance and 3GPP Security Interworking |  | 147d? | 2005-03-10 A | 2005-09-30 | 80% | 29.4d? | 2005-03-10 | 2005-09-30 | 147d? | 640d | finish no earlier than 2005-09-30 | S3 | 1176h | 940.8h | LibSec | Silke Holtmanns, Nokia | Silke.Holtmanns@NOKIA.COM | Rel-7 | TSG | Maurice | 33.980 |  |
| 164 | 36 | **WLAN-UMTS Interworking Phase 2** |  | 371d? | 2004-01-05 A | 2005-06-07 | 99% | 0d? | 2004-01-05 | 2005-06-07 | 371d? | 809d |  | S1 | 3888h | 3888h | WLAN2 | Fredric Paint, Telenor | frederic.paint@telenor.com | Rel-7 | TSG | Michael |  |  |
| 165 | 36.1 | Stage 1 on Session Continuity |  | 115d? | 2004-01-05 A | 2004-06-11 A | 100% |  | 2004-01-05 | 2004-06-11 | 115d? |  | start no earlier than 2004-01-05 | S1 | 920h | 920h | WLAN-SC |  |  | Rel-7 |  |  |  | SP-24 |
| 166 | 36.2 | Stage 2 on Session Continuity: covered by SAE | milestone | 0d? | 2005-06-07 | 2005-06-07 |  |  | 2005-06-07 | 2005-06-07 | 0d? | 724d | finish no earlier than 2005-06-07 | S2 |  |  |  |  |  | Rel-7 |  |  |  |  |
| 167 | 37 | **WLAN Interworking – Private Network access from WLAN 3GPP IP Access** |  | 252d? | 2005-10-10 A | 2006-09-26 | 76% | 61.64d? | 2005-10-10 | 2006-09-26 | 252d? | 468d |  | S2 | 6920h | 5106.67h | WLANPNA |  |  | Rel-7 |  | Maurice |  |  |
| 168 | 37.1 | WLAN-PNA - Stage 2 |  | 185d? | 2005-10-10 A | 2006-06-23 A | 100% |  | 2005-10-10 | 2006-06-23 | 185d? |  | start no earlier than 2005-10-10 | S2 | 1480h | 1480h | WLANPNA-st2 | Toshiyuki Tamura (NEC) | tamurato@aj.jp.nec.com | Rel-7 |  | Maurice | 23.234, 33.234 |  |
| 169 | 37.2 | **WLAN-PNA - Stage 3** |  | 170d? | 2006-02-01 A | 2006-09-26 | 67% | 56.67d? | 2006-02-01 | 2006-09-26 | 170d? | 468d |  | C1 | 5440h | 3626.67h | WLANPNA-st3 | Pierre-Jean Muller (NEC) | pierre-jean.muller@nectech.fr | Rel-7 | TSG | Andrijana |  |  |
| 170 | 37.2.1 | CT1 aspets for WLAN-PNA |  | 170d? | 2006-02-01 A | 2006-09-26 A | 100% |  | 2006-02-01 | 2006-09-26 | 170d? |  | start no earlier than 2006-02-01 | C1 | 1360h | 1360h | WLANPNA-st3 | Pierre-Jean Muller (NEC) | pierre-jean.muller@nectech.fr | Rel-7 |  | Andrijana | 24.234 |  |
| 171 | 37.2.2 | CT3 aspets for WLAN-PNA |  | 170d? | 2006-02-01 A | 2006-09-26 A | 100% |  | 2006-02-01 | 2006-09-26 | 170d? |  | start no earlier than 2006-02-01 | C3 | 1360h | 1360h | WLANPNA-st3 | Pierre-Jean Muller (NEC) | pierre-jean.muller@nectech.fr | Rel-7 |  | Andrijana | 29.161 |  |
| 172 | 37.2.3 | CT4 aspets for WLAN-PNA |  | 170d? | 2006-02-01 | 2006-09-26 |  |  | 2006-02-01 | 2006-09-26 | 170d? | 468d | start no earlier than 2006-02-01 | C4 | 1360h |  | WLANPNA-st3 | Pierre-Jean Muller (NEC) | pierre-jean.muller@nectech.fr | Rel-7 |  | Andrijana | 29.234 |  |
| 173 | 38 | **Enhancements to support QoS provisioning over 3GPP/WLAN Interworking** |  | 340d? | 2005-03-14 A | 2006-06-30 A | 100% |  | 2005-03-14 | 2006-06-30 | 340d? |  |  | S2 | 5440h | 5440h | WLAN-QOS | Osok Song, Samsung | osok.song@samsung.com | Rel-7 |  | Maurice | 23.836 |  |
| 174 | 38.1 | TR on support of QoS on WLAN |  | 232d? | 2005-03-14 A | 2006-01-31 A | 100% |  | 2005-03-14 | 2006-01-31 | 232d? |  | start no earlier than 2005-03-14 | S2 | 1856h | 1856h |  |  |  | Rel-7 |  |  |  |  |
| 175 | 38.2 | Stage 2 on support of QoS over 3GPP/WLAN interworking |  | 108d? | 2006-02-01 A | 2006-06-30 A | 100% |  | 2006-02-01 | 2006-06-30 | 108d? |  | start no earlier than 2006-02-01 | S2 | 864h | 864h |  |  |  | Rel-7 |  |  |  |  |
| 176 | 39 | **Voice call continuity between CS and IMS (incl. I-WLAN)** |  | 511d? | 2004-12-31 A | 2006-12-15 | 43% | 289.27d? | 2004-12-31 | 2006-12-15 | 511d? | 410d |  | S2 | 17120h | 5953.87h | VCC | Andy Bennett, Lucent; Roger Bunting, Cingular | andybennett@lucent.com | Rel-7 |  | Maurice | 22.101, 23.228, 32.250, 32.260, 32.299, 32.298 |  |
| 177 | 39.1 | TR for VCC |  | 245d? | 2004-12-31 A | 2005-12-08 A | 100% |  | 2004-12-31 | 2005-12-08 | 245d? |  | finish no earlier than 2005-12-08 | S2 | 1960h | 1960h |  |  |  | Rel-7 |  |  | 23.806 |  |
| 178 | 39.2 | Stage 1 for VCC |  | 140d? | 2005-03-17 A | 2005-09-28 A | 100% |  | 2005-03-17 | 2005-09-28 | 140d? |  | finish no earlier than 2005-09-28 | S1 | 1120h | 1120h |  |  |  | Rel-7 |  | Mike |  |  |
| 179 | 39.3 | Stage 2 for VCC |  | 264d? | 2005-09-06 A | 2006-09-08 | 60% | 105.6d? | 2005-09-06 | 2006-09-08 | 264d? | 480d | finish no earlier than 2006-09-08 | S2 | 2112h | 1267.2h |  |  |  | Rel-7 |  |  | 23.206 |  |

Notes:
- 155: az: WID URL corrected
- 158: CT#30: WID approved.
- 163: WID approved SA#27.
- 164: Created at TSG#27 by A. Sultan because of WLAN items belonging to Rel-7
- 167: Placeholder created to Hold SA2 and CT1 BBs
- 168: Approved at SP#29
- 169: Approved at CP#29
- 170: Approved at CP#29
- 171: Approved at CP#29
- 172: Approved at CP#29...
- 173: Moved from FS section Feb 06
- 176: WID approved SA#27. Revised at SA#28. WID update approved at SA#32

| ID | WBS | Task | Duration | Start | Finish | Complete | Remaining | Baseline start | Baseline finish | Baseline duration | Total slack | Constraint | Resources | Work | Actual work | Text4 | Text5 | Text6 | Text1 | Text8 | Text7 |
| --- | --- | --- | --- | --- | --- | --- | --- | --- | --- | --- | --- | --- | --- | --- | --- | --- | --- | --- | --- | --- | --- |
| 180 | 39.4 | **Stage 3 for VCC** | 196d? | 2006-02-01 A | 2006-11-01 | 13% | 169.87d? | 2006-02-01 | 2006-11-01 | 196d? | 442d |  | C1 | 6272h | 836.27h | Keith Drage (Lucent) | drage@lucent.com | Rel-7 |  |  |  |
| 181 | 39.4.1 | CT1 aspects of VCC | 196d? | 2006-02-01 A | 2006-11-01 | 40% | 117.6d? | 2006-02-01 | 2006-11-01 | 196d? | 442d | start no earlier than 2006-02-01 | C1 | 1568h | 627.2h | Keith Drage (Lucent) | drage@lucent.com | Rel-7 |  |  |  |
| 182 | 39.4.2 | CT3 aspects of VCC | 196d? | 2006-02-01 | 2006-11-01 |  |  | 2006-02-01 | 2006-11-01 | 196d? | 442d | start no earlier than 2006-02-01 | C3 | 1568h |  | Keith Drage (Lucent) | drage@lucent.com | Rel-7 |  |  |  |
| 183 | 39.4.3 | CT4 aspects of VCC | 196d? | 2006-02-01 | 2006-11-01 |  |  | 2006-02-01 | 2006-11-01 | 196d? | 442d | start no earlier than 2006-02-01 | C4 | 1568h |  | Keith Drage (Lucent) | drage@lucent.com | Rel-7 |  |  |  |
| 184 | 39.5 | SA5 Charging aspects of VCC | 196d? | 2006-03-17 | 2006-12-15 |  |  | 2006-03-17 | 2006-12-15 | 196d? | 410d | finish no earlier than 2006-12-15 | S5 | 1568h |  | Orange | alain.bibas@orange-ft.com | Rel-7 | VCC-CH | Adrian |  |
| 185 | 40 | **OAM&P** | 740d? | 2004-02-16 A | 2006-12-15 | 46% | 400.55d? | 2004-02-16 | 2006-12-15 | 740d? | 410d |  | S5 | 88609.1h | 37462.6h | Christian TOCHE | Christian.Toche@huawei.com | Rel-7 | OAM7 | Adrian | TSG |
| 186 | 40.1 | **Network Infrastructure Management** | 336d? | 2005-09-02 A | 2006-12-15 | 45% | 185.93d? | 2005-09-02 | 2006-12-15 | 336d? | 410d |  | S5 | 41152h | 17179.2h |  |  | Rel-7 | OAM7-NIM |  |  |
| 187 | 40.1.1 | Enhance NRM to accommodate NGN (IMS as basis of the Next Generation Network) | 336d? | 2005-09-02 A | 2006-12-15 | 20% | 268.8d? | 2005-09-02 | 2006-12-15 | 336d? | 410d | finish no earlier than 2006-12-15 | S5 | 2688h | 537.6h | BT |  | Rel-7 |  |  |  |
| 188 | 40.1.2 | Co-operative Element Management interface (CO-OP) (Study + Implementation) | 336d? | 2005-09-02 A | 2006-12-15 | 90% | 33.6d? | 2005-09-02 | 2006-12-15 | 336d? | 410d | finish no earlier than 2006-12-15 | S5 | 2688h | 2419.2h | Motorola |  | Rel-7 |  |  |  |
| 189 | 40.1.3 | Network Management (NM) Itf-N performance criteria | 336d? | 2005-09-02 A | 2006-12-15 | 35% | 218.4d? | 2005-09-02 | 2006-12-15 | 336d? | 410d | finish no earlier than 2006-12-15 | S5 | 2688h | 940.8h | China Mobile |  | Rel-7 |  |  |  |
| 190 | 40.1.4 | Delta synchronization between IRP Manager and IRP Agent (Study + Implementation) | 336d? | 2005-09-02 A | 2006-12-15 | 60% | 134.4d? | 2005-09-02 | 2006-12-15 | 336d? | 410d | finish no earlier than 2006-12-15 | S5 | 2688h | 1612.8h | Siemens |  | Rel-7 |  |  |  |
| 191 | 40.1.5 | Subscription Management (SuM) IRP Solution Sets | 336d? | 2005-09-02 A | 2006-12-15 | 55% | 151.2d? | 2005-09-02 | 2006-12-15 | 336d? | 410d | finish no earlier than 2006-12-15 | S5 | 2688h | 1478.4h | Ericsson |  | Rel-7 |  |  |  |
| 192 | 40.1.6 | Integration Reference Point (IRP) Security Management | 336d? | 2005-09-02 A | 2006-12-15 | 55% | 151.2d? | 2005-09-02 | 2006-12-15 | 336d? | 410d | finish no earlier than 2006-12-15 | S5 | 2688h | 1478.4h | Huawei |  | Rel-7 |  |  |  |
| 193 | 40.1.7 | Integration Reference Point (IRP) Methodology | 336d? | 2005-09-02 A | 2006-12-15 | 35% | 218.4d? | 2005-09-02 | 2006-12-15 | 336d? | 410d | finish no earlier than 2006-12-15 | S5 | 2688h | 940.8h | Ericsson |  | Rel-7 |  |  |  |
| 194 | 40.1.8 | Partial suspension of Itf-N during maintenance/testing (Study + Implementation) | 336d? | 2005-09-02 A | 2006-12-15 | 75% | 84d? | 2005-09-02 | 2006-12-15 | 336d? | 410d | finish no earlier than 2006-12-15 | S5 | 2688h | 2016h | Siemens |  | Rel-7 |  |  |  |
| 195 | 40.1.9 | Advanced Alarming on Itf-N (Study + Implementation) | 336d? | 2005-09-02 A | 2006-12-15 | 45% | 184.8d? | 2005-09-02 | 2006-12-15 | 336d? | 410d | finish no earlier than 2006-12-15 | S5 | 2688h | 1209.6h | Siemens |  | Rel-7 |  |  |  |
| 196 | 40.1.10 | Management of Legacy Equipment | 336d? | 2005-09-02 A | 2006-12-15 | 20% | 268.8d? | 2005-09-02 | 2006-12-15 | 336d? | 410d | finish no earlier than 2006-12-15 | S5 | 2688h | 537.6h | Siemens |  | Rel-7 |  |  |  |
| 197 | 40.1.11 | Rules for Vendor Specific Extensions | 336d? | 2005-09-02 A | 2006-12-15 | 20% | 268.8d? | 2005-09-02 | 2006-12-15 | 336d? | 410d | finish no earlier than 2006-12-15 | S5 | 2688h | 537.6h | Siemens |  | Rel-7 |  |  |  |
| 198 | 40.1.12 | CN CS Bearer Transport Network (BTN) relative NRM | 336d? | 2005-09-02 A | 2006-12-15 | 55% | 151.2d? | 2005-09-02 | 2006-12-15 | 336d? | 410d | finish no earlier than 2006-12-15 | S5 | 2688h | 1478.4h | China Mobile |  | Rel-7 |  |  |  |
| 199 | 40.1.13 | Backward and Forward Compatibility of IRP systems | 336d? | 2005-09-02 A | 2006-12-15 | 25% | 252d? | 2005-09-02 | 2006-12-15 | 336d? | 410d | finish no earlier than 2006-12-15 | S5 | 2688h | 672h | Ericsson |  | Rel-7 |  |  |  |
| 200 | 40.1.14 | Repeater Network Resource Model (NRM) definition | 220d? | 2006-02-13 A | 2006-12-15 | 10% | 198d? | 2006-02-13 | 2006-12-15 | 220d? | 410d | start no earlier than 2006-02-13 | S5 | 1760h | 176h | China Mobile |  | Rel-7 |  |  |  |
| 201 | 40.1.15 | UTRAN radio channel power monitoring | 220d? | 2006-02-13 A | 2006-12-15 | 65% | 77d? | 2006-02-13 | 2006-12-15 | 220d? | 410d | start no earlier than 2006-02-13 | S5 | 1760h | 1144h | China Mobile |  | Rel-7 |  |  |  |
| 202 | 40.2 | **Performance Management** | 336d? | 2005-09-02 A | 2006-12-15 | 46% | 182.97d? | 2005-09-02 | 2006-12-15 | 336d? | 410d |  | S5 | 20576h | 8147.2h |  |  | Rel-7 | OAM7-PM |  |  |
| 203 | 40.2.1 | Performance measurements definition for CN CS | 336d? | 2005-09-02 A | 2006-12-15 | 70% | 100.8d? | 2005-09-02 | 2006-12-15 | 336d? | 410d | finish no earlier than 2006-12-15 | S5 | 2688h | 1881.6h | China Mobile |  | Rel-7 |  |  |  |
| 204 | 40.2.2 | Enhancement UTRAN performance measurements definition | 336d? | 2005-09-02 A | 2006-12-15 | 30% | 235.2d? | 2005-09-02 | 2006-12-15 | 336d? | 410d | finish no earlier than 2006-12-15 | S5 | 2688h | 806.4h | China Mobile |  | Rel-7 |  |  |  |
| 205 | 40.2.3 | Add TDD specific counters in Performance measurement | 336d? | 2005-09-02 A | 2006-12-15 | 95% | 16.8d? | 2005-09-02 | 2006-12-15 | 336d? | 410d | finish no earlier than 2006-12-15 | S5 | 2688h | 2553.6h | CATT |  | Rel-7 |  |  |  |
| 206 | 40.2.4 | ATM bearer network Performance measurements | 336d? | 2005-09-02 A | 2006-12-15 | 55% | 151.2d? | 2005-09-02 | 2006-12-15 | 336d? | 410d | finish no earlier than 2006-12-15 | S5 | 2688h | 1478.4h | ZTE |  | Rel-7 |  |  |  |
| 207 | 40.2.5 | IP bearer network Performance measurement definitions | 336d? | 2005-09-02 A | 2006-12-15 | 20% | 268.8d? | 2005-09-02 | 2006-12-15 | 336d? | 410d | finish no earlier than 2006-12-15 | S5 | 2688h | 537.6h | China Mobile |  | Rel-7 |  |  |  |
| 208 | 40.2.6 | Performance measurements definition for IMS | 336d? | 2005-09-02 A | 2006-12-15 | 20% | 268.8d? | 2005-09-02 | 2006-12-15 | 336d? | 410d | finish no earlier than 2006-12-15 | S5 | 2688h | 537.6h | China Mobile |  | Rel-7 |  |  |  |
| 209 | 40.2.7 | HSDPA performance measurements | 220d? | 2006-02-13 A | 2006-12-15 | 20% | 176d? | 2006-02-13 | 2006-12-15 | 220d? | 410d | start no earlier than 2006-02-13 | S5 | 1760h | 352h | China Mobile |  | Rel-7 |  |  |  |

Notes:
- 180: Text3: new TS, 24.229, 23.008, 23.009, 23.078, 29.078, 29.163, 29.228, 29.229, 29.230, 29.278, 29.328, 29.329
- 181: Text3: new TS, 24.229
- 182: Text3: 29.163
- 183: Text3: 23.008, 23.009, 23.078, 29.078, 29.228, 29.229, 29.230, 29.278, 29.328, 29.329
- 184: 03/2006 SA#31 WID approved / Text3: 32.250, 32.260, 32.298, 32.299
- 187: Text3: 32.632, 32.633, 32.634, 32.635
- 188: Text3: new TR 32.806, 32.101
- 189: Text3: new TS 32.yzx
- 190: Text3: new TR 32.8xy, new TSs 32.111-n,32.60n; For n = 1 to 5
- 191: Text3: 32.101,32.175, new TSs 32.161,32.307,32.317,32.607,32.617,32.667
- 192: Text3: new TSs 32.372,32.373,32.374; 32.111,32.30x,32.32x,32.33x,32.34x,32.35x,32.36x,32.41x,32.60x,32.61x,32.66x
- 193: Text3: new TSs 32.15w,32.15x,32.15y,32.15z; 32.150,32.151,32.152
- 194: Text3: new TR 32.8xy, new TSs 32.38x,32.60n,32.61n; For n = 1 to 5
- 195: Text3: new TR 32.8xy ; new TSs 32.111-n,32.30n; For n = 1 to 5
- 196: Text3: new TS 32.xxx, new TSs 32.62n,32.63n,32.64n,32.65n,32.71n,32.74n,32.69n; For n = 1 to 5
- 197: Text3: 32.62n; For n = 1 to 5
- 198: Text3: new TSs 32.xx1,32.xx2, 32.xx3, 32.xx4
- 199: Text3: new TR 32.805. new TS 32.15X
- 200: Text3: 32.64n; For n = 1 to 5
- 201: Text3: 32.405, 32.64n; For n = 1 to 5
- 203: Text3: 32.407, 32.408
- 204: Text3: 32.405
- 205: Text3: 32.405
- 206: Text3: 32.404,32.405,32.406,32.407
- 207: Text3: 32.404,32.405,32.406,32.407
- 208: Text3: 32.404,32.409,32.437, 32.632/3/4/5
- 209: Text3: 32.405

| ID | WBS | Task | Type | Duration | Start | Finish | Complete | Remaining | Baseline start | Baseline finish | Baseline duration | Total slack | Constraint | Resources | Work | Actual work | Text1 | Text4 | Text6 | Text7 | Text12 | Text5 | Text8 |
| --- | --- | --- | --- | --- | --- | --- | --- | --- | --- | --- | --- | --- | --- | --- | --- | --- | --- | --- | --- | --- | --- | --- | --- |
| 210 | 44.5 | **Trace Management** |  | 740d? | 2004-02-16 A | 2006-12-15 | 49% | 377.13d? | 2004-02-16 | 2006-12-15 | 740d? | 410d |  | S5 | 20961.1h | 8344.24h | OAM7-Trace | Vodafone | Rel-7 | TSG |  |  |  |
| 211 | 40.3.1 | Deleted - Trace Management for IMS (merged with 35062) |  | 420d? | 2005-05-09 A | 2006-12-15 A | 100% |  | 2005-05-09 | 2006-12-15 | 420d? |  | finish no earlier than 2006-12-15 | S5 | 3360h | 3360h |  | Nortel | Rel-7 | TSG | SP-31 |  |  |
| 212 | 40.3.2 | End-to-end Service Level tracing for IMS |  | 286d? | 2005-11-11 A | 2006-12-15 | 40% | 171.6d? | 2005-11-11 | 2006-12-15 | 286d? | 410d | finish no earlier than 2006-12-15 | S5 | 2288h | 915.2h |  | Vodafone | Rel-7 | TSG |  |  |  |
| 213 | 40.3.3 | Trace record content for UTRAN TDD |  | 420d? | 2005-05-09 A | 2006-12-15 | 95% | 21d? | 2005-05-09 | 2006-12-15 | 420d? | 410d | finish no earlier than 2006-12-15 | S5 | 3360h | 3192h |  | CATT | Rel-7 | TSG |  |  |  |
| 214 | 40.3.4 | IRP for Subscriber and Equipment Trace Management |  | 336d? | 2005-09-02 A | 2006-12-15 | 20% | 268.8d? | 2005-09-02 | 2006-12-15 | 336d? | 410d | finish no earlier than 2006-12-15 | S5 | 2688h | 537.6h |  | Nokia | Rel-7 | TSG |  |  |  |
| 215 | 40.3.5 | SIP enhancements for trace |  | 603.14d? | 2004-02-16 A | 2006-06-16 | 2% | 591.08d? | 2004-02-16 | 2006-06-16 | 603.14d? | 540d | finish no earlier than 2006-06-16 | C1 | 4825.12h | 96.5h | OAM7-Trace-SIP |  | Rel-7 |  |  |  |  |
| 216 | 41 | Trust Requirements for Open Platforms in 3GPP |  | 115d? | 2005-01-03 A | 2005-06-10 | 40% | 69d? | 2005-01-03 | 2005-06-10 | 115d? | 805d | finish no earlier than 2005-06-10 | S3 | 920h | 368h | TrustOP | Silke Holtmanns, Nokia | Rel-7 | TSG |  | Silke.Holtmanns@NOKIA.COM | Michael |
| 217 | 42 | Development of UEA2 and UIA2 |  | 268d? | 2004-12-01 A | 2005-12-09 | 80% | 53.6d? | 2004-12-01 | 2005-12-09 | 268d? | 675d | finish no earlier than 2005-12-09 | S3 | 2144h | 1715.2h | AlgUEA2 | Per Christoffersson, Teliasonera | Rel-7 | TSG |  | per.christoffersson@teliasonera.com | Michael |
| 218 | 43 | Lawful Interception in the 3GPP Rel-7 architecture |  | 118d? | 2005-06-28 A | 2005-12-08 | 70% | 35.4d? | 2005-06-28 | 2005-12-08 | 118d? | 676d | start no earlier than 2005-06-28 | S3 | 944h | 660.8h | LI-7A | Berthold Wilhelm, BMWI | Rel-7 |  |  | berthold.wilhelm@regtp.de | Mike |
| 219 | 44 | **Support of Conversational Services in A/Gb mode via the PS domain** |  | 681d? | 2005-04-08 A | 2007-11-16 | 4% | 654.59d? | 2005-04-08 | 2006-12-19 | 442.05d? | 170d |  | GP | 18842.8h | 730.65h | SCSAGB | Gunnar Hedby, Ericsson | Rel-7 |  |  | gunnar.hedby@ericsson.com | Paolo |
| 220 | 44.1 | Minimise the transfer delay between the SGSN and the MS |  | 659.95d? | 2005-04-08 A | 2007-11-16 | 10% | 593.96d? | 2005-04-08 | 2006-12-19 | 421d? | 170d | finish no earlier than 2007-11-16 | GP | 5279.6h | 527.96h | SCSAGB-MTD |  | Rel-7 |  |  |  |  |
| 221 | 44.2 | Definition of radio resource management functionality |  | 681d? | 2005-04-08 | 2007-11-16 |  |  | 2005-04-08 | 2006-11-17 | 421d? | 170d | finish no earlier than 2007-11-16 | G1 | 5448h |  | SCSAGB-RRM | Gunnar Hedby, Ericsson | Rel-7 |  |  | gunnar.hedby@ericsson.com | Paolo |
| 222 | 44.3 | Deleted- Radio Channel Support | milestone | 0d? | 2006-07-17 A | 2006-07-17 A | 100% |  | 2005-04-08 | 2006-11-17 | 421d? |  | start no earlier than 2006-07-17 | G2 |  |  | SCSAGB-RCHS | Gunnar Hedby, Ericsson | Rel-7 |  | SP-32 | gunnar.hedby@ericsson.com | Gert |
| 223 | 44.4 | Deleted- Modifications to FLO | milestone | 0d? | 2006-07-17 A | 2006-07-17 A | 100% |  | 2005-04-08 | 2006-11-17 | 421d? |  | start no earlier than 2006-07-17 | G2 |  |  | SCSAGB-FLO | Gunnar Hedby, Ericsson | Rel-7 |  | SP-32 | gunnar.hedby@ericsson.com | Gert |
| 224 | 44.5 | Support of Conversational Services in A/Gb mode via the PS domain – RLC Non-Persistent mode |  | 361d? | 2006-06-30 | 2007-11-16 |  |  |  |  |  | 170d | finish no earlier than 2007-11-16 | G2 | 2888h |  | SCSAGB-RLCNP | Gunnar Hedby, Ericsson | Rel-7 |  |  | gunnar.hedby@ericsson.com | Gert |
| 225 | 45 | **Addition of new frequency band to GSM (T-GSM810)** |  | 421d? | 2005-04-08 A | 2006-11-17 | 97% | 12.97d? | 2005-04-08 | 2006-06-30 | 321d? | 430d |  | GP | 8832h | 5295.6h | TGSM810 | Chen De, Huawei | Rel-7 |  |  | chende@huawei.com | Paolo |
| 226 | 45.1 | Changes to core specification |  | 106d? | 2005-04-08 A | 2005-09-02 A | 100% |  | 2005-04-08 | 2005-09-02 | 106d? |  | finish no earlier than 2005-09-02 | GP | 848h | 848h | TGSM810-Core | Chen De, Huawei | Rel-7 |  |  | chende@huawei.com | Paolo |
| 227 | 45.2 | Changes to MS testing specification |  | 421d? | 2005-04-08 A | 2006-11-17 | 95% | 21.05d? | 2005-04-08 | 2006-06-30 | 321d? | 430d | finish no earlier than 2006-11-17 | G3 | 3368h | 3199.6h | TGSM810-MStest | Chen De, Huawei | Rel-7 |  |  | chende@huawei.com | Stoyan |
| 228 | 45.3 | Changes to BTS testing specification |  | 156d? | 2005-04-08 A | 2005-11-11 A | 100% |  | 2005-04-08 | 2005-11-11 | 156d? |  | finish no earlier than 2005-11-11 | G1 | 1248h | 1248h | TGSM810-BTStest | Chen De, Huawei | Rel-7 |  |  | chende@huawei.com | Paolo |
| 229 | 46 | **Handover of dedicated and shared resources while in dual transfer mode** |  | 421d? | 2005-04-08 A | 2006-11-17 | 28% | 304.8d? | 2005-04-08 | 2006-11-17 | 421d? | 430d |  | GP | 12672h | 2568h | HODSRDTM | Rami Vaittinen, Nokia | Rel-7 |  |  | rami.vaittinen@nokia.com | Paolo |
| 230 | 46.1 | Handover of dedicated and shared resources while in dual transfer mode |  | 321d? | 2005-04-08 A | 2006-06-30 A | 100% |  | 2005-04-08 | 2006-06-30 | 321d? |  | finish no earlier than 2006-06-30 | G2 | 2568h | 2568h | HODSRDTM-G2 | Rami Vaittinen, Nokia | Rel-7 |  |  | rami.vaittinen@nokia.com | Gert |
| 231 | 46.2 | MS Conformance Testing |  | 421d? | 2005-04-08 | 2006-11-17 |  |  | 2005-04-08 | 2006-11-17 | 421d? | 430d | finish no earlier than 2006-11-17 | G3 | 3368h |  | HODSRDTM-Mstest | Rami Vaittinen, Nokia | Rel-7 |  |  | rami.vaittinen@nokia.com | Stoyan |
| 232 | 46.3 | BTS conformance testing |  | 421d? | 2005-04-08 | 2006-11-17 |  |  | 2005-04-08 | 2006-11-17 | 421d? | 430d | finish no earlier than 2006-11-17 | G1 | 3368h |  | HODSRDTM-BTStest | Rami Vaittinen, Nokia | Rel-7 |  |  | rami.vaittinen@nokia.com | Paolo |
| 233 | 47 | Future GERAN Evolution |  | 371d? | 2005-04-08 A | 2006-09-08 | 90% | 37.1d? | 2005-04-08 | 2006-06-30 | 321d? | 480d | finish no earlier than 2006-09-08 | GP | 2968h | 2671.2h | FGE | Eddie Riddington, Nokia Corporation | Rel-7 |  |  | eddie.riddington@nokia.com | Paolo |
| 234 | 48 | 3G-324M Video Telephony Call Setup Times Improvements |  | 341d? | 2005-06-08 A | 2006-09-27 | 60% | 136.4d? | 2005-06-08 | 2006-09-27 | 341d? | 467d | finish no earlier than 2006-09-27 | S4 | 2728h | 1636.8h | VTCSTI | Edward Hall (Vodafone) | Rel-7 |  |  | edward.hall@vodafone.co.uk | Paolo |

Notes:
- 211: Text3: 32.421,32.422,32.423
- 212: 07/2005: OMA (Stage 1), Stage 2/3 SA5, CT1/3/4 / Text3: 32.101,32.421,32.422,32.423
- 213: Text3: 32.421,32.422,32.423
- 214: Text3: 32.421,32.422,32.423. 3 new TS 32.4x1,2,3
- 216: WID approved SA#26. Record created after SA#27
- 217: WID approved SA#26, Dependant on Funding Availability. Record created after SA#27 / Text3: 35.919, 35.215, 35.216, 35.217, 35.218
- 218: Text3: 33.106, 33.107, 33.108
- 219: Originally started Nov. 2003 as GP-030443
- 224: Text3: 43.955, 43.064, 44.060, 45.001, 45.002, 45.003, 45.005, 45.010, 51.010, 51.021
- 225: Text3: 45.005, 45.050, 24.008, 45.008, 45.001, 43.022, 43.030, 44.018, 44.060, 51.010-1, 51.021
- 226: Text3: 45.005, 45.050, 24.008, 45.008, 45.001, 43.022, 43.030, 44.018, 44.060
- 227: Started / Text3: 51010-1
- 228: Text3: 51021
- 229: Started at GERAN#24
- 230: Started at GERAN#24 / Text3: 43.055, 44.018, 44.060
- 231: Not started / Text3: 51-010
- 232: Not started / Text3: 51.026
- 233: FS started
- 234: Conditionally, in the event Phase 2 is needed, end is Dec.06 / Text3: 26.abc

| ID | WBS | Task | Type | Duration | Start | Finish | Complete | Remaining | Baseline start | Baseline finish | Baseline duration | Total slack | Constraint | Resources | Work | Actual work | Text1 | Text3 | Text4 | Text5 | Text6 | Text8 | Text7 | Text12 |
| --- | --- | --- | --- | --- | --- | --- | --- | --- | --- | --- | --- | --- | --- | --- | --- | --- | --- | --- | --- | --- | --- | --- | --- | --- |
| 235 | 49 | **Identification of Communication Services in IMS** |  | 425d? | 2005-05-02 A | 2006-12-15 | 50% | 211.36d? | 2005-05-02 | 2006-12-15 | 425d? | 410d |  | S2 | 9384h | 3136h | ServID | 22.228, 23.228, 23.203, 32.260, 32.298, 32.299 | Stephen Terrill, Ericsson | stephen.terrill@ericsson.com | Rel-7 | Maurice |  |  |
| 236 | 49.1 | TR for ICS |  | 232d? | 2005-05-02 A | 2006-03-21 A | 100% |  | 2005-05-02 | 2006-03-21 | 232d? |  | finish no earlier than 2006-03-20 | S2 | 1856h | 1856h |  | 23.816 |  |  | Rel-7 |  |  |  |
| 237 | 49.2 | Stage 2 of ICS |  | 144d? | 2005-11-11 A | 2006-05-31 A | 100% |  | 2005-11-11 | 2006-05-31 | 144d? |  | start no earlier than 2005-11-11 | S2 | 1152h | 1152h |  |  |  |  | Rel-7 |  |  |  |
| 238 | 49.3 | Stage 3 of ICS |  | 186d? | 2006-03-31 | 2006-12-15 |  |  | 2006-03-31 | 2006-12-15 | 186d? | 410d | finish no earlier than 2006-12-15 | C1 | 1488h |  |  |  | Christer Holmberg (Ericsson) | christer.holmberg@ericsson.com | Rel-7 | Andrijana |  |  |
| 239 | 49.4 | SA5 Charging aspects of ServID |  | 186d? | 2006-03-31 | 2006-12-15 |  |  | 2006-03-31 | 2006-12-15 | 186d? | 410d | finish no earlier than 2006-12-15 | S5 | 1488h |  | ServID-CH | 32.260, 32.298, 32.299 | Orange | alain.bibas@orange-ft.com | Rel-7 | Adrian |  |  |
| 240 | 50 | **VoIMS bearer related enhancements** |  | 354d? | 2005-03-15 A | 2006-07-21 | 99% | 0d? | 2005-03-15 | 2006-07-21 | 354d? | 0d |  | S2 | 4303.2h | 1576h | VoIMS |  |  |  | Rel-7 |  |  |  |
| 241 | 50.1 | Improved support of IMS Realtime Services using HSDPA/HSUPA |  | 197d? | 2005-03-15 A | 2005-12-14 A | 100% |  | 2005-03-15 | 2005-12-14 | 197d? |  | start no earlier than 2005-03-15 | R2 | 1576h | 1576h | RANimp-IMSRealTime |  | Don Zelmer | don.zelmer@CINGULAR.COM | Rel-7 | MCC_RAN | TSG |  |
| 242 | 50.2 | Deleted - FS on enhancement of radio performance for VoIMS | milestone | 0d? | 2006-07-21 A | 2006-07-21 A | 100% |  | 2006-07-21 | 2006-07-21 | 0d? |  | start no earlier than 2006-07-21 | S2 |  |  | VoIMS | 23.807 | Laurence Lautier, Nortel Networks | lautierl@nortel.com | Rel-7 | Maurice |  | SP-32 |
| 243 | 51 | Performance Characterization of VoIMS over HSDPA\EUL channels |  | 453d? | 2005-03-15 A | 2006-12-07 | 20% | 362.4d? | 2005-03-15 | 2006-12-07 | 453d? | 416d | finish no earlier than 2006-12-07 | S4 | 3624h | 724.8h | VoIMS-PCVoIMS | 26.935 | Dimitris Vasilaras (Lucent Technologies) | dvasilaras@lucent.com | Rel-7 | Paolo | TSG |  |
| 244 | 52 | **Optimizations for Multimedia Telephony over IMS** |  | 312d? | 2005-09-28 A | 2006-12-07 | 50% | 156d? | 2005-09-28 | 2006-12-07 | 312d? | 416d |  | S4 | 4992h | 1978.8h | OMTIMS | 26.235, 26.236 | Olle Franceschi (Ericsson) | olle.franceschi@ericsson.com | Rel-7 | Paolo |  |  |
| 245 | 52.1 | Characterisation of Adaptive Jitter Management Performance for VoIP Services |  | 312d? | 2005-09-28 A | 2006-12-07 | 50% | 156d? | 2005-09-28 | 2006-12-07 | 312d? | 416d | finish no earlier than 2006-12-07 | S4 | 2496h | 1248h | OMTIMS-CAJMP |  | David Huo (Lucent Technologies) | dhuo@lucent.com | Rel-7 | Paolo |  |  |
| 246 | 53 | End-to-End Multimedia Services Performance Metrics |  | 312d? | 2005-09-28 A | 2006-12-07 | 20% | 249.6d? | 2005-09-28 | 2006-12-07 | 312d? | 416d | finish no earlier than 2006-12-07 | S4 | 2496h | 499.2h | E2EMSPM |  | Zhang Yan (China Mobile) | zhangyanyf@chinamobile.com | Rel-7 | Paolo |  |  |
| 247 | 54 | **Supporting Globally Routable User Agent URIs in IMS** |  | 280d? | 2005-11-14 A | 2006-12-08 | 41% | 163.82d? | 2005-11-14 | 2006-09-15 | 220d? | 415d |  | S2 | 3400h | 1377.6h | GRUU | 23.8XX, 22.228, 23.228, 23.218, 24.229 | Adrian Buckley (Research In Motion) | abuckley@rim.com | Rel-7 | Maurice |  |  |
| 248 | 54.1 | TR on GRUU |  | 219d? | 2005-11-14 A | 2006-09-14 | 60% | 87.6d? | 2005-11-14 | 2006-09-14 | 219d? | 476d | finish no earlier than 2006-09-14 | S2 | 1752h | 1051.2h |  |  |  |  | Rel-7 | Maurice |  |  |
| 249 | 54.2 | Stage 2 of GRUU |  | 60d? | 2006-06-26 | 2006-09-15 |  |  | 2006-06-26 | 2006-09-15 | 60d? | 475d | finish no earlier than 2006-09-15 | S2 | 480h |  |  |  |  |  | Rel-7 | Maurice |  |  |
| 250 | 54.3 | Stage 3 of GRUU |  | 136d? | 2006-06-02 A | 2006-12-08 | 30% | 95.2d? | 2006-06-26 | 2006-09-15 | 60d? | 415d | finish no earlier than 2006-12-08 | C1 | 1088h | 326.4h |  |  | Bernie McKibben, CableLabs |  | Rel-7 | Andrijana |  |  |
| 251 | 55 | ISIM API for Java Card |  | 200d? | 2005-03-14 A | 2005-12-16 | 90% | 20d? | 2005-03-14 | 2005-12-16 | 200d? | 670d | finish no earlier than 2005-12-16 | C6 | 1600h | 1440h | APIJAVA | 31.103, TS 102 241 | Sebastian Hans, Sun Microsystems Ltd. |  | Rel-7 | Gaby |  |  |
| 252 | 56 | **Rel7 Security enhancements** |  | 241d? | 2005-09-12 A | 2006-08-14 | 88% | 28.37d? | 2005-09-12 | 2006-08-14 | 241d? | 499d |  | S3 | 6168h | 4520.88h | SEC7 |  |  |  | Rel-7 |  |  |  |
| 253 | 56.1 | HTTPS connection between a UICC and a NAF |  | 1d? | 2005-09-12 A | 2005-09-12 A | 100% |  | 2005-09-12 | 2005-09-12 | 1d? |  | start no earlier than 2005-09-12 | S3 | 8h | 8h | SEC7-HSUN | 33.222, 24.109, 33.918 | Jacques Seif (Axlato) | JSeif@axalto.com | Rel-7 |  |  |  |
| 254 | 56.2 | 2G GBA: 2G SIM usage in 3GPP GAA framework |  | 61d? | 2005-09-12 A | 2005-12-05 | 98% | 1.22d? | 2005-09-12 | 2005-12-05 | 61d? | 679d | finish no earlier than 2005-12-05 | S3 | 488h | 478.24h | SEC7-2GGBA | 33.220, 33.290 | Silke Holtmanns (Nokia) | Silke.Holtmanns@nokia.com | Rel-7 |  |  |  |
| 255 | 56.3 | Generic Authentication Architecture usage extensions and optimisations |  | 1d? | 2005-09-12 A | 2005-09-12 | 70% | 0.3d? | 2005-09-12 | 2005-09-12 | 1d? | 739d | start no earlier than 2005-09-12 | S3 | 8h | 5.6h | SEC7-GAA2 | 33.220, 29.109 | Silke Holtmanns (Nokia) | Silke.Holtmanns@nokia.com | Rel-7 |  |  |  |
| 256 | 56.4 | **SS7 TCAP security Gateway** |  | 241d? | 2005-09-12 A | 2006-08-14 | 86% | 34.66d? | 2005-09-12 | 2006-08-14 | 241d? | 499d |  | S3 | 3736h | 2328h | SEC7-NDS-TCAPsec | 33.200, 33.204 | Marc Blommaert (Siemens) | marc.blommaert@siemens.com | Rel-7 |  |  |  |
| 257 | 56.4.1 | SA3 aspects of SEC7-NDS-TCAPsec |  | 130d? | 2005-09-12 A | 2006-03-10 | 75% | 32.5d? | 2005-09-12 | 2006-03-10 | 130d? | 610d | finish no earlier than 2006-03-10 | S3 | 1040h | 780h | SEC7-NDS-TCAPsec-SA3 | 33.200, 33.204 | Marc Blommaert (Siemens) | marc.blommaert@siemens.com | Rel-7 |  |  |  |
| 258 | 56.4.2 | TCAPsec Gateway |  | 96d? | 2006-04-03 A | 2006-08-14 A | 100% |  | 2006-04-03 | 2006-08-14 | 96d? |  | start no earlier than 2006-04-01 | C4 | 768h | 768h | SEC7-NDS-TCAPsec-CT4 | new TS 29.204 | Ulrich Wiehe, Siemens | Ulrich.wiehe@gksag.de | Rel-7 | Kimmo |  |  |
| 259 | 57 | Network Composition |  | 211d? | 2005-12-07 A | 2006-09-27 | 50% | 105.5d? | 2005-12-07 | 2006-09-27 | 211d? | 467d | finish no earlier than 2006-09-27 | S1 | 1688h | 844h | NetComp | 22.980 | Joerg Swetina (Siemens) | joerg.swetina@siemens.com | Rel-7 |  |  |  |
| 260 | 58 | Key establishment between a UICC and a terminal |  | 201.45d? | 2005-12-07 A | 2006-09-28 | 70% | 60.44d? | 2005-12-07 | 2006-09-28 | 201.45d? | 466d | finish no earlier than 2006-09-28 | S3 | 1611.6h | 1128.12h | KeyEstUTerm | 33.110 | Mireille Pauliac (Gemplus) | mireille.pauliac@gemplus.com | Rel-7 |  |  |  |

Notes:
- 235: WID approved SA#28. Updated WID approved SA#32
- 239: 03/2006 SA#31 WID approved
- 240: Created by MCC to group all VoIMS related items, after consultation of chairs
- 242: WID approved SA#28: SA2#52: CLOSED - To be removed from the work plan
- 247: Approved at SP#29
- 248: S2#52: "GURU" corrected to "GRUU"
- 249: S2#52: "GURU" corrected to "GRUU"
- 250: S2#52: "GURU" corrected to "GRUU"
- 258: Study WI...

| ID | WBS | Task | Duration | Start | Finish | Complete | Remaining | Baseline start | Baseline finish | Baseline duration | Total slack | Constraint | Resources | Work | Actual work | Text1 | Text3 | Text4 | Text5 | Text6 | Text8 | Text7 |
| --- | --- | --- | --- | --- | --- | --- | --- | --- | --- | --- | --- | --- | --- | --- | --- | --- | --- | --- | --- | --- | --- | --- |
| 261 | 59 | **Mobile Station Receive Diversity (DARP Phase II)** | 311d? | 2005-11-11 A | 2007-01-19 | 9% | 283.09d? | 2005-11-11 | 2007-01-19 | 311d? | 385d |  | GP | 10920h | 980.11h | MSRD2 | 24.008, 45.005, 51.010 | Kent Pedersen, Nokia Corporation (ETSI) | kent.pedersen@nokia.com | Rel-7 | Paolo |  |
| 262 | 59.1 | MS conformance test of DARP Phase II (MSRD) | 311d? | 2005-11-11 | 2007-01-19 |  |  | 2005-11-11 | 2007-01-19 | 311d? | 385d | finish no earlier than 2007-01-19 | GP | 2488h |  | MSRD2-Msconf | 51.010 | Kent Pedersen, Nokia Corporation (ETSI) | kent.pedersen@nokia.com | Rel-7 | Paolo, Stoyan |  |
| 263 | 59.2 | Performance Requirements for Mobile Station Receive Diversity, DARP Phase II | 216d? | 2005-11-11 A | 2006-09-08 | 15% | 183.6d? | 2005-11-11 | 2006-09-08 | 216d? | 480d | finish no earlier than 2006-09-08 | GP | 1728h | 259.2h | MSRD2-PerfReq | 45.005 | Kent Pedersen, Nokia Corporation (ETSI) | kent.pedersen@nokia.com | Rel-7 | Paolo |  |
| 264 | 59.3 | Capability signalling of Mobile Station Receive Diversity, DARP Phase II | 216d? | 2005-11-11 | 2006-09-08 |  |  | 2005-11-11 | 2006-09-08 | 216d? | 480d | finish no earlier than 2006-09-08 | GP | 1728h |  | MSRD2-CapSig | 24.008 | Kent Pedersen, Nokia Corporation (ETSI) | kent.pedersen@nokia.com | Rel-7 | Paolo, Gert |  |
| 265 | 59.4 | Test Scenarios for Mobile Station Receive Diversity, DARP Phase II | 311d? | 2005-11-11 A | 2007-01-19 | 20% | 248.8d? | 2005-11-11 | 2007-01-19 | 311d? | 385d | finish no earlier than 2007-01-19 | GP | 2488h | 497.6h | MSRD2-TestSc | 45.005 | Kent Pedersen, Nokia Corporation (ETSI) | kent.pedersen@nokia.com | Rel-7 | Paolo |  |
| 266 | 60 | MBMS Enhancements | 109d? | 2005-07-11 A | 2005-12-08 | 75% | 27.25d? | 2005-07-11 | 2005-12-08 | 109d? | 676d | finish no earlier than 2005-12-08 | S1 | 872h | 654h | MBMSE |  | Liu Hong, China Mobile | liuhongyfw@chinamobile.com | Rel-7 | Mike |  |
| 267 | 61 | MBMS User Service Extensions | 262d? | 2005-12-07 A | 2006-12-07 | 20% | 209.6d? | 2005-12-07 | 2006-12-07 | 262d? | 416d | finish no earlier than 2006-12-07 | S4 | 2096h | 419.2h | MBMSUSE | 26.346, 26.946 | Thorsten Lohmar (Ericsson) | Thorsten.Lohmar@ericsson.com | Rel-7 | Paolo |  |
| 268 | 62 | IMS Support of Conferencing and Messaging Group Management | 221d? | 2005-11-04 A | 2006-09-08 | 25% | 165.75d? | 2005-11-04 | 2006-09-08 | 221d? | 480d | finish no earlier than 2006-09-08 | C1 | 1768h | 442h | IMSconf |  | Keith Drage (Lucent) | drage@lucent.com | Rel-7 | Andrijana |  |
| 269 | 63 | **Selective Disabling of UE Capabilities** | 489.36d? | 2005-01-24 A | 2006-12-08 | 85% | 75.72d? | 2005-01-24 | 2006-12-08 | 489.36d? | 415d |  | S1 | 9356.8h | 7908.94h | SDoUE | 22.xxx | Nigel Barnes (Motorola Ltd) | Nigel.Barnes@motorola.com | Rel-7 | Michael | TSG |
| 270 | 63.1 | Stage 1 of SDoUE | 393.6d? | 2005-01-24 A | 2006-12-08 A | 100% |  | 2005-01-24 | 2006-12-08 | 393.6d? |  | finish no earlier than 2006-12-08 | S1 | 3148.8h | 3148.8h | SDoUE-CRs | 22.011 | Nigel Barnes (Motorola Ltd) | Nigel.Barnes@motorola.com | Rel-7 | Michael | TSG |
| 271 | 63.2 | TR on different possible architectures | 195d? | 2005-03-21 A | 2005-12-16 A | 100% |  | 2005-03-21 | 2005-12-16 | 195d? |  | finish no earlier than 2005-12-16 | S2 | 1560h | 1560h |  | 23.805 |  |  | Rel-7 | Maurice |  |
| 272 | 63.3 | Stage 3 of SDoUE | 131d? | 2006-03-10 A | 2006-09-08 | 15% | 111.35d? | 2006-03-10 | 2006-09-08 | 131d? | 480d | finish no earlier than 2006-09-08 | C1 | 1048h | 157.2h |  | New TS 24.305 | Christian Herrero (Ericsson) | christian.herrero@ericsson.com | Rel-7 | Andrijana |  |
| 273 | 64 | **Personal Network Management (PNM)** | 276d? | 2005-07-11 A | 2006-07-31 | 91% | 25.79d? | 2005-07-11 | 2006-07-31 | 276d? | 509d |  | S1 | 5689.6h | 5157.88h | PNPAN |  | Armin Toepfer, Vodafone | armin.toepfer@vodafone.com | Rel-7 | Mike |  |
| 274 | 64.1 | Study of PNPAM | 167d? | 2005-07-11 A | 2006-02-28 A | 100% |  | 2005-07-11 | 2006-02-28 | 167d? |  | start no earlier than 2005-07-11 | S1 | 1336h | 1336h |  |  |  |  | Rel-7 |  |  |
| 275 | 64.2 | Stage 1 of PNPAM | 276d? | 2005-07-11 A | 2006-07-31 | 85% | 41.4d? | 2005-07-11 | 2006-07-31 | 276d? | 509d | start no earlier than 2005-07-11 | S1 | 2208h | 1876.8h |  | 22.259 |  |  | Rel-7 |  |  |
| 276 | 65 | **Multimedia Telephony Service for IMS** | 265d? | 2006-03-10 A | 2007-03-15 | 43% | 150.96d? | 2006-03-15 | 2007-03-15 | 262d? | 346d |  | S1 | 7288h | 2242.4h | MTSI |  | Peter Bleckert, Ericsson | peter.bleckert @ericsson.com | Rel-7 | Mike |  |
| 277 | 65.1 | Stage 1 of MTSI | 191d? | 2006-03-15 A | 2006-12-06 A | 100% |  | 2006-03-15 | 2006-12-06 | 191d? |  | start no earlier than 2006-03-15 | S1 | 1528h | 1528h | MTSI-REQ | 22.173 | Peter Bleckert, Ericsson | peter.bleckert @ericsson.com | Rel-7 | Mike |  |
| 278 | 65.2 | Stage 3 of MTSI | 196d? | 2006-03-10 A | 2006-12-08 | 25% | 147d? | 2006-03-10 | 2006-09-08 | 131d? | 415d | finish no earlier than 2006-12-08 | C1 | 1568h | 392h |  | New TS 24.173 | Christer Holmberg (Ericsson) | christer.holmberg@ericsson.com | Rel-7 | Andrijana |  |
| 279 | 65.3 | Media handling and interaction in MTSI | 262d? | 2006-03-15 A | 2007-03-15 | 15% | 222.7d? | 2006-03-15 | 2007-03-15 | 262d? | 346d | finish no earlier than 2007-03-15 | S4 | 2096h | 314.4h | MTSI-MHI | 26.114, 26.235, 26.236 | Olle Franceschi, Ericsson | olle.franceschi@ericsson.com | Rel-7 | Paolo |  |
| 280 | 66 | **Multimedia interworking between IMS and CS networks** | 381d? | 2005-09-23 A | 2007-03-09 | 30% | 266.69d? | 2005-09-23 | 2006-06-02 | 181d? | 350d |  | C3 | 6487.99h | 1075.51h | MIW-IMS | 29.163 | Nico Gabriele, Vodafone UK | nico.gabriele@vodafone.com | Rel-7 | Seung Don |  |
| 281 | 66.1 | Note: Stages 1 and 2 defined in earlier Release | 49d? | 2005-09-23 A | 2005-11-30 A | 100% |  | 2005-09-23 | 2005-11-30 | 49d? |  | start no earlier than 2005-09-23 | S2 | 392h | 392h |  |  |  |  | Rel-7 |  |  |
| 282 | 66.2 | Stage 3 of MW-IMS | 381d? | 2005-09-23 A | 2007-03-09 | 21% | 300.99d? | 2005-09-23 | 2006-06-02 | 181d? | 350d | finish no earlier than 2007-03-09 | C3 | 3048h | 640.08h |  | 29.163 |  |  | Rel-7 |  |  |
| 283 | 67 | **Network selection enhancements** | 192d? | 2006-03-15 A | 2006-12-07 | 53% | 90.76d? | 2006-03-15 | 2006-12-06 | 191d? | 416d |  | S1 | 4144h | 2019.2h | NSP-CR | 22.101, 22.011, 23.122, 24.008, 25.304, 31.102, 45.008 | Chris Friel, O2 | chris.friel@o2.com | Rel-7 | Michael |  |
| 284 | 67.1 | Stage 1 of NSP | 191d? | 2006-03-15 A | 2006-12-06 | 90% | 19.1d? |  |  |  | 417d | start no earlier than 2006-03-15 | S1 | 1528h | 1375.2h | NSP-TS | 22.101, 22.011, 23.122, 24.008, 25.304, 31.102, 45.008 | Chris Friel, O2 | chris.friel@o2.com | Rel-7 | Michael |  |
| 285 | 67.2 | Procedural aspects of NSP | 135d? | 2006-06-02 | 2006-12-07 |  |  |  |  |  | 416d | finish no earlier than 2006-12-07 | C1 | 1080h |  |  | 23.122, 24.008, 31.102 | Andrew Howell (Motorola) | andrew.howell@motorola.com | Rel-7 | Andrijana |  |

Notes:
- 261: Started
- 269: Moved from FS section Feb 06
- 270: Moved from FS section Feb 06
- 271: Moved from FS section Feb 06
- 273: Moved from FS section Feb 06
- 274: Moved from FS section Feb 06
- 275: Moved from FS section Feb 06
- 278: TS 24.173:IMS Multimedia telephony service and supplementary services
- 280: Moved from FS section Feb 06
- 281: Moved from FS section Feb 06

| ID | WBS | Task | Type | Duration | Start | Finish | Complete | Remaining | Baseline start | Baseline finish | Baseline duration | Total slack | Constraint | Resources | Work | Actual work | Text1 | Text4 | Text5 | Text6 | Text8 | Text7 | Text12 |
| --- | --- | --- | --- | --- | --- | --- | --- | --- | --- | --- | --- | --- | --- | --- | --- | --- | --- | --- | --- | --- | --- | --- | --- |
| 286 | 68 | **Interoperability between VGCS/VBS and A/Gb flexibility** |  | 133d? | 2006-03-22 A | 2006-09-22 | 30% | 93.1d? | 2006-03-22 | 2006-09-22 | 133d? | 470d |  | C1 | 3192h | 957.6h | VGCSFlex | Robert Zaus (Siemens) | robert.zaus@siemens.com | Rel-7 | Andrijana |  |  |
| 287 | 68.1 | CT1 aspects of VGCSFlex |  | 133d? | 2006-03-22 A | 2006-09-22 | 40% | 79.8d? | 2006-03-22 | 2006-09-22 | 133d? | 470d | finish no earlier than 2006-09-22 | C1 | 1064h | 425.6h |  |  |  | Rel-7 |  |  |  |
| 288 | 68.2 | CT4 aspects of VGCSFlex |  | 133d? | 2006-03-22 A | 2006-09-22 | 20% | 106.4d? | 2006-03-22 | 2006-09-22 | 133d? | 470d | finish no earlier than 2006-09-22 | C4 | 1064h | 212.8h |  |  |  | Rel-7 |  |  |  |
| 289 | 69 | **One Tunnel solution for Optimisation of Packet Data Traffic** |  | 190d? | 2006-03-27 A | 2006-12-15 | 16% | 159.55d? | 2006-03-27 | 2006-12-15 | 190d? | 410d |  | S2 | 3080h | 493.59h | OPTUNEL | Antti Pasanen (Nokia) |  | Rel-7 | Maurice |  |  |
| 290 | 69.1 | Stage 2 Study for One Tunnel solution |  | 125d? | 2006-03-27 A | 2006-09-15 | 25% | 93.75d? | 2006-03-27 | 2006-09-15 | 125d? | 475d | finish no earlier than 2005-09-12 | S2 | 1000h | 250h | OPTUNEL-Study | Antti Pasanen (Nokia) |  | Rel-7 | Maurice | TSG |  |
| 291 | 69.2 | Stage 2 specification for One Tunnel solution |  | 70d? | 2006-09-11 | 2006-12-15 |  |  | 2006-09-11 | 2006-12-15 | 70d? | 410d | finish no earlier than 2006-12-15 | S2 | 560h |  | OPTUNEL-Stage2 | Antti Pasanen (Nokia) |  | Rel-7 | Maurice | TSG |  |
| 292 | 70 | **Downlink Dual Carrier** |  | 346d? | 2006-01-20 A | 2007-05-18 | 17% | 286.8d? | 2006-01-20 | 2007-05-18 | 346d? | 300d |  | GP | 9920h | 928h | GDCDL | Leonardo Provvedi, Siemens AG | leonardo.provvedi@roke.co.uk | Rel-7 | Paolo |  |  |
| 293 | 70.1 | Downlink Dual Carrier Stage 2 |  | 116d? | 2006-01-20 A | 2006-06-30 A | 100% |  | 2006-01-20 | 2006-06-30 | 116d? |  | finish no earlier than 2006-06-30 | G1 | 928h | 928h | GDCDL-Stage2 | Leonardo Provvedi, Siemens AG | leonardo.provvedi@roke.co.uk | Rel-7 | Paolo |  |  |
| 294 | 70.2 | Downlink Dual Carrier Stage 3 |  | 216d? | 2006-01-20 | 2006-11-17 |  |  | 2006-01-20 | 2006-11-17 | 216d? | 430d | start no earlier than 2006-01-20 | G2;; G1 | 3456h |  | GDCDL-Stage3 | Leonardo Provvedi, Siemens AG | leonardo.provvedi@roke.co.uk | Rel-7 | Gert, Paolo |  |  |
| 295 | 70.3 | Downlink Dual Carrier – MS Conformance Test |  | 346d? | 2006-01-20 | 2007-05-18 |  |  | 2006-01-20 | 2007-05-18 | 346d? | 300d | start no earlier than 2006-01-20 | G3 | 2768h |  | GDCDL-MStest | Leonardo Provvedi, Siemens AG | leonardo.provvedi@roke.co.uk | Rel-7 | Stoyan |  |  |
| 296 | 71 | Support of SIGTRAN in GERAN |  | 116d? | 2006-01-20 A | 2006-06-30 A | 100% |  | 2006-01-20 | 2006-06-30 | 116d? |  | finish no earlier than 2006-06-30 | GP | 928h | 928h | GSIGT | Peter Ostrup, Ericsson | peter.ostrup@ericsson.com | Rel-7 | Paolo |  |  |
| 297 | 72 | Packet Switched Streaming Enhancements |  | 131d? | 2006-06-08 | 2006-12-07 |  |  | 2006-01-20 | 2006-06-30 | 116d? | 416d | finish no earlier than 2006-12-07 | S4 | 1048h |  | PSSe | Olle Franceschi (Ericsson) | olle.franceschi@ericsson.com | Rel-7 | Paolo |  |  |
| 298 | 73 | **Enhanced USIM Phonebook** |  | 261d? | 2006-06-22 | 2007-06-21 |  |  | 2006-01-20 | 2006-06-30 | 116d? | 276d |  | C6 | 5224h |  | eUPHBOOK | Claus Dietze (Giesecke & Devrient) |  | Rel-7 |  |  |  |
| 299 | 73.1 | Requirements for eUPHBOOK |  | 131d? | 2006-06-22 | 2006-12-21 |  |  | 2006-01-20 | 2006-06-30 | 116d? | 406d | start no earlier than 2006-06-22 | C6 | 1048h |  |  |  |  | Rel-7 |  |  |  |
| 300 | 73.2 | Implementation of eUPHBOOK |  | 261d? | 2006-06-22 | 2007-06-21 |  |  | 2006-01-20 | 2006-06-30 | 116d? | 276d | finish no earlier than 2007-06-21 | C6 | 2088h |  |  |  |  | Rel-7 |  |  |  |
| 301 | 74 | **Charging Management small Enhancements** |  | 150d? | 2006-05-22 | 2006-12-15 |  |  |  |  |  | 410d |  | S5 | 2400h |  | CH7 | Orange | alain.bibas@francetelecom.com | Rel-7 | Adrian |  |  |
| 302 | 74.1 | Alternate Charged Party (ACP) for IMS |  | 150d? | 2006-05-22 | 2006-12-15 |  |  |  |  |  | 410d | start no earlier than 2006-05-22 | S5 | 1200h |  | CH7-IMS-ACP | Lucent | njmazzarella@lucent.com | Rel-7 |  |  |  |
| 303 | 75 | **Latency Reductions** |  | 361d? | 2006-06-30 | 2007-11-16 |  |  |  |  |  | 170d |  | GP | 7624h |  | LATRED | Håkan Persson, Ericsson | Hakan.Persson@Ericsson.com |  | Paolo |  |  |
| 304 | 75.1 | Improved Ack/Nack reporting |  | 361d? | 2006-06-30 | 2007-11-16 |  |  |  |  |  | 170d | finish no earlier than 2007-11-16 | G2 | 2888h |  | LATRED-ACKNAR | Håkan Persson, Ericsson | Hakan.Persson@Ericsson.com |  | Gert |  |  |
| 305 | 75.2 | Reduced TTI |  | 231d? | 2006-06-30 | 2007-05-18 |  |  |  |  |  | 300d | finish no earlier than 2007-05-18 | G2 | 1848h |  | LATRED-REDTTI | Håkan Persson, Ericsson | Hakan.Persson@Ericsson.com |  | Gert |  |  |
| 306 | 76 | PS Handover between GERAN/UTRAN mode and GAN Mode |  | 166d? | 2006-06-30 | 2007-02-16 |  |  |  |  |  | 365d | finish no earlier than 2007-02-16 | G2 | 1328h |  | GUGAN | John Diachina, Ericsson | John.Diachina@Ericsson.com |  | Gert |  |  |
| 307 | 77 | CSI Terminating Session handling |  | 82d? | 2006-06-08 | 2006-09-29 |  |  |  |  |  | 465d | finish no earlier than 2006-09-29 | S2 | 656h |  | CSItermS | Osok Song (Samsung) |  |  | Maurice |  |  |
| 308 | 78 | (Small) Technical Enhancements and Improvements for Rel-7 |  | 400d? | 2005-06-06 | 2006-12-15 |  |  | 2005-06-06 | 2006-12-15 | 400d? | 410d | finish no earlier than 2006-12-15 | All | 3200h |  | TEI7 |  |  | Rel-7 |  |  |  |
| 309 | 79 | **Deleted - PS domain and IMS support for IMS Emergency sessions** |  | 63.69d? | 2006-06-23 A | 2006-09-21 A | 100% |  | 2005-10-10 | 2006-06-23 | 185d? |  |  | S2 |  |  | IMS-EMER | Curt Wong (Nokia) | curt.c.wong@nokia.com | Rel-7 | Maurice |  | SP-30 |
| 310 | 79.1 | Deleted - IMS aspects to support IMS Emergency sessions | milestone | 0d? | 2006-06-23 A | 2006-09-21 A | 100% |  | 2005-10-10 | 2006-06-23 | 121.31d? |  | start no earlier than 2006-06-23 | S2 |  |  |  | Curt Wong (Nokia) | curt.c.wong@nokia.com | Rel-7 | Maurice | TSG | SP-30 |
| 311 | 79.2 | Deleted - PS domain aspects to support IMS Emergency sessions | milestone | 0d? | 2006-06-23 A | 2006-09-21 A | 100% |  | 2005-10-10 | 2006-06-23 | 121.31d? |  | start no earlier than 2006-06-23 | S2 |  |  |  | Curt Wong (Nokia) | curt.c.wong@nokia.com | Rel-7 | Maurice | TSG | SP-30 |
| 312 | 80 | Deleted - Covered by SI - Personal Network (PN) and Personal Area Network (PAN) | milestone | 0d? | 2005-12-08 A | 2005-12-20 A | 100% |  | 2005-07-11 | 2005-12-08 | 101.2d? |  | start no earlier than 2005-12-08 | S1 |  |  | PNPAN | Armin Toepfer, Vodafone | armin.toepfer@vodafone.com | Rel-7 | Mike |  | SP-30 |
| 313 | 81 | Deleted - Covered by SI - Multimedia Telephony Capabilities for IMS | milestone | 0d? | 2005-12-08 A | 2005-12-20 A | 100% |  | 2005-07-11 | 2005-12-08 | 101.2d? |  | start no earlier than 2005-12-08 | S1 |  |  | MITE | Peter Bleckert, Ericsson | peter.bleckert @ericsson.com | Rel-7 | Mike |  | SP-30 |
| 314 | 82 | Deleted - Covered by SI - Transferring of emergency Call data | milestone | 0d? | 2005-12-08 A | 2005-12-08 A | 100% |  | 2005-07-11 | 2005-12-08 | 109d? |  | start no earlier than 2005-12-08 | S1 |  |  | eCALL | Steve Vardy, (Motorola S.A.S) | steven.vardy@motorola.com | Rel-7 | Mike |  | SP-30 |
| 315 | 83 | Deleted - Covered by SI - MBMS Enhancements | milestone | 0d? | 2005-12-08 A | 2005-12-08 A | 100% |  | 2005-07-11 | 2005-12-08 | 109d? |  | start no earlier than 2005-12-08 | S1 |  |  | MBMSE | Liu Hong, China Mobile | liuhongyfw@chinamobile.com | Rel-7 | Mike |  | SP-30 |
| 316 | 84 | Rel-7 Feasibility Studies |  | 1d? | 2000-01-03 | 2000-01-03 |  |  | 2000-01-03 | 2000-01-03 | 1d? | 2224d |  | CT;RAN;SA | 8h |  |  |  |  | Rel-7 |  |  |  |

Notes:
- 286: Text3: 43.068, 43.069, 29.002
- 287: Text3: 43.068, 43.069
- 288: Text3: 29.002
- 290: S2#52 CREATED / Text3: 23.8de
- 291: S2#52 CREATED / Text3: 23.060
- 292: Text3: 24.008, 43.055, 43.064, 44.018, 44.060, 45.001, 45.002, 45.005, 45.008, 51.010
- 293: Text3: 43.055, 43.064
- 294: Text3: 24.008, 44.018, 44.060, 45.001, 45.002, 45.005, 45.008
- 295: Text3: 51.010
- 296: Text3: 48.001, 48.006, 43.059, 49.031
- 297: Text3: 26.234, 26.244
- 299: Text3: 21.111
- 300: Text3: 31.102
- 301: Text3: 32.2xy
- 302: Text3: 32.240, 32.260, 32.298, 32.299
- 303: Text3: 45.001, 45.002, 45.003, 45.005, 45.010, 43.055, 43.064, 44.060, 51.010-1, 51.021
- 304: Text3: 45.001, 45.002, 45.003, 45.005, 45.010, 43.055, 43.064, 44.060, 51.010-1, 51.021
- 305: Text3: 45.001, 45.002, 45.003, 45.005, 45.010, 43.055, 43.064, 44.060, 51.010-1, 51.021
- 306: Text3: 43.318, 44.318, 43.129, 25.306, 24.008, 44.060, 25.331, 51.010
- 307: Not to be confused with FS with same name / Text3: 23.228, 23.279
- 309: Approved at SP#29 / Text3: 23.867, TS 23.abc, 23.060, 23.002, 23.271
- 310: Approved at SP#29 / Text3: 23.867, TS 23.abc, 23.060, 23.002, 23.271
- 311: Approved at SP#29 / Text3: 23.867, TS 23.abc, 23.060, 23.002, 23.271

| ID | WBS | Task | Duration | Start | Finish | Complete | Remaining | Baseline start | Baseline finish | Baseline duration | Total slack | Constraint | Resources | Work | Actual work | Text1 | Text5 | Text6 | Text8 | Text3 | Text7 |
| --- | --- | --- | --- | --- | --- | --- | --- | --- | --- | --- | --- | --- | --- | --- | --- | --- | --- | --- | --- | --- | --- |
| 317 | 85 | **Multimedia Telephony Capabilities for IMS** | 320d? | 2005-07-11 A | 2006-09-29 A | 100% |  | 2005-07-11 | 2006-09-29 | 320d? |  |  | S1 | 6089.6h | 6089.6h | MITE | peter.bleckert @ericsson.com | Rel-7 | Mike |  |  |
| 318 | 85.1 | Study of (MITe) - IMS Multimedia Telephony Communication Enabler and supplementary services | 276d? | 2005-07-11 A | 2006-07-31 A | 100% |  | 2005-07-11 | 2006-07-31 | 276d? |  | start no earlier than 2005-07-11 | S1 | 2208h | 2208h |  | peter.bleckert @ericsson.com | Rel-7 | Mike | 22.973 |  |
| 319 | 85.2 | IMS Multimedia Telephony Service | 173d? | 2006-02-01 A | 2006-09-29 A | 100% |  | 2006-02-01 | 2006-09-29 | 173d? |  | start no earlier than 2006-02-01 | S1 | 1384h | 1384h |  | peter.bleckert @ericsson.com | Rel-7 | Mike | 22.173 |  |
| 320 | 86 | Study Item on IMS enhancements and optimisations for real time communication. | 315d? | 2005-10-10 A | 2006-12-22 | 45% | 173.25d? | 2005-10-10 | 2006-12-22 | 315d? | 405d | finish no earlier than 2006-12-22 | S2 | 2520h | 1134h | IMS-RT | stephen.terrill@ericsson.com | Rel-7 | Maurice | 23.818 |  |
| 321 | 87 | Behaviour of Multi system UEs | 480d? | 2004-06-28 A | 2006-04-28 | 90% | 48d? | 2004-06-28 | 2006-04-28 | 480d? | 575d | start no earlier than 2004-06-28 | S1 | 3840h | 3456h | BMSU | dwilliams@qualcomm.com | Rel-7 | Michael | 22.936 | TSG |
| 322 | 88 | **FS on IMS with real time services deployment** | 384d? | 2004-06-28 A | 2005-12-15 | 99% | 0d? | 2004-06-28 | 2005-12-15 | 384d? | 0d |  | S1 | 8672h | 6304.24h | IRTSD |  | Rel-7 | Maurice |  | TSG |
| 323 | 88.1 | Feasibility Study on Combining CS calls and IMS sessions | 384d? | 2004-06-28 A | 2005-12-15 A | 100% |  | 2004-06-28 | 2005-12-15 | 384d? |  | start no earlier than 2004-06-28 | S1 | 3072h | 3072h | IRTSD-CS_IMS |  | Rel-7 | Michael | 22.979, 23.899 | TSG |
| 324 | 88.2 | TR on Stage 2 (IMS services using CS bearers) | 316d? | 2004-06-28 A | 2005-09-12 A | 100% |  | 2004-06-28 | 2005-09-12 | 316d? |  | finish no earlier than 2005-09-12 | S2 | 2528h | 2528h | IRTSD-IMSCS |  | Rel-7 | Maurice | 23.899 | TSG |
| 325 | 89 | (FS on) Terminating Session handling | 190d? | 2006-01-09 A | 2006-09-29 | 60% | 76d? | 2006-01-09 | 2006-09-29 | 190d? | 465d | start no earlier than 2006-01-09 | S2 | 1520h | 912h | CSIterm | osok.song@samsung.com | Rel-7 | Maurice |  |  |
| 326 | 90 | Study of work on an LCS architecture for I-WLAN | 120d? | 2006-06-26 | 2006-12-08 |  |  | 2006-06-26 | 2006-12-08 | 120d? | 415d | finish no earlier than 2006-12-08 | S2 | 960h |  |  | dhshim@lge.com ; phede@lge.com | Rel-7 | Maurice |  |  |
| 327 | 91 | FS on Performance Evaluation of the UE behaviour in high speed trains with speeds up to 350 kmph | 328d? | 2005-03-15 A | 2006-06-15 A | 100% |  | 2005-03-15 | 2006-06-15 | 328d? |  | finish no earlier than 2006-06-15 | R4 | 2624h | 2624h | RANFS-HSTrains | Mike.vogel@vodafone.com | Rel-7 | MCC_RAN |  | TSG |
| 328 | 92 | FS on Evolved UTRA and UTRAN | 197d? | 2004-12-15 A | 2005-09-15 | 85% | 29.55d? | 2004-12-15 | 2005-06-15 | 130d? | 736d | finish no earlier than 2005-09-15 | RP | 1576h | 1339.6h | RANFS-Evo | nakamurata@NTTDOCOMO.CO.JP | Rel-7 | MCC_RAN |  | TSG |
| 329 | 93 | **Study on Videotelephony teleservice** | 231d? | 2005-03-01 A | 2006-01-17 A | 100% |  | 2005-03-01 | 2006-01-17 | 231d? |  |  | S1 | 3696h | 3696h | VidTel | kurt.bischinger@t-mobile.at | Rel-7 | Michael |  | TSG |
| 330 | 93.1 | Study on Videotelephony service requirements | 231d? | 2005-03-01 A | 2006-01-17 A | 100% |  | 2005-03-01 | 2006-01-17 | 231d? |  | start no earlier than 2005-03-01 | S1 | 1848h | 1848h |  | kurt.bischinger@t-mobile.at | Rel-7 | Michael | 22.903 | TSG |
| 331 | 94 | **Study of Network Selection Principles** | 193d? | 2005-03-15 A | 2005-12-08 | 99% | 0d? | 2005-03-15 | 2005-12-08 | 193d? | 0d |  | S1 | 3088h | 2658.02h | NetSel | chris.friel@o2.com | Rel-7 | Michael |  | TSG |
| 332 | 94.1 | Review of Network Selection Principles | 193d? | 2005-03-15 A | 2005-12-08 A | 100% |  | 2005-03-15 | 2005-12-08 | 193d? |  | finish no earlier than 2005-12-08 | S1 | 1544h | 1544h |  | chris.friel@o2.com | Rel-7 | Michael | 22.811 | TSG |
| 333 | 95 | FS on Continuous connectivity for packet data users | 132d? | 2005-03-15 A | 2005-09-15 A | 100% |  | 2005-03-15 | 2005-09-15 | 132d? |  | finish no earlier than 2005-09-15 | R1 | 1056h | 1056h | RANFS-cont-packet | joerg.gustrau@siemens.com | Rel-7 | MCC_RAN |  | TSG |
| 334 | 96 | FS on UTRA Tower Mounted Amplifier (FDD) | 195d? | 2005-06-15 A | 2006-03-14 A | 100% |  | 2005-06-15 | 2006-03-14 | 195d? |  | finish no earlier than 2006-03-15 | R4 | 1560h | 1560h | RANFS-TMA | Klas.Sjerling@ericsson.com | Rel-7 | MCC_RAN |  | TSG |
| 335 | 97 | Multimedia Priority Service | 851d? | 2003-03-28 A | 2006-06-30 A | 100% |  | 2003-03-28 | 2006-06-30 | 851d? |  | finish no earlier than 2005-12-16 | S1 | 6808h | 6808h | PRIOR-MM | jgarraha@telcordia.com | Rel-7 | Michael | 22.953 |  |
| 336 | 98 | Transferring of emergency Call data | 190d? | 2005-07-11 A | 2006-03-31 A | 100% |  | 2005-07-11 | 2006-03-31 | 190d? |  | finish no earlier than 2005-12-08 | S1 | 1520h | 1520h | eCALL | steven.vardy@motorola.com | Rel-7 | Mike | 22.967 |  |
| 337 | 99 | Study of a SMS Centre for MT SMS | 191d? | 2005-10-07 A | 2006-06-30 | 44% | 107d? | 2005-10-07 | 2006-06-30 | 191d? | 530d | start no earlier than 2005-10-07 | C4 | 1528h | 672h | SMS7 | Nick.Russell@vodafone.com | Rel-7 | Kimmo | 23.840 |  |
| 338 | 100 | FS on Improvement of the Multimedia Broadcast Multicast Service (MBMS) in UTRAN | 262d? | 2005-12-15 A | 2006-12-15 | 50% | 131d? | 2005-12-15 | 2006-09-15 | 197d? | 410d | finish no earlier than 2006-12-15 | R2 | 2096h | 1048h | RANFS-MBMSImp | leego@lge.com | Rel-7 | MCC_RAN |  |  |
| 339 | 101 | FS on Performance Improvements in Small Cells using HSDPA/EDCH | 131d? | 2005-12-15 A | 2006-06-15 A | 100% |  | 2005-12-15 | 2006-06-15 | 131d? |  | finish no earlier than 2006-06-15 | R4 | 1048h | 1048h | SMALLCELLS | marc.grant@cingular.com | Rel-7 | MCC_RAN |  |  |
| 340 | 102 | FS on Further Improved Performance Requirements for UMTS/HSDPA UE (FDD) | 262d? | 2005-12-15 A | 2006-12-15 | 40% | 157.2d? | 2005-12-15 | 2006-12-15 | 262d? | 410d | finish no earlier than 2006-12-15 | R4 | 2096h | 838.4h | RANFS-IC | marc.grant@cingular.com | Rel-7 | MCC_RAN |  |  |
| 341 | 103 | FS on the TCAPsec Gateway concept | 96d? | 2005-10-28 A | 2006-03-10 A | 100% |  | 2005-10-28 | 2006-03-10 | 96d? |  | finish no earlier than 2006-03-10 | C4 | 768h | 768h | SEC7-TCAP | Ulrich.wiehe@gksag.de | Rel-7 | Kimmo | 29.800 |  |
| 342 | 104 | Study of Customised Alerting Tone (CAT) Requirements | 191d? | 2005-10-07 A | 2006-06-30 | 60% | 76.4d? | 2005-10-07 | 2006-06-30 | 191d? | 530d | start no earlier than 2005-10-07 | S1 | 1528h | 916.8h | CAT | fenglingjuan@chinamobile.com | Rel-7 | Michael | 22.982 |  |
| 343 | 105 | SI on Scope of future FDD HSPA Evolution | 198d? | 2006-03-15 A | 2006-12-15 | 10% | 178.2d? | 2006-03-15 | 2006-12-15 | 198d? | 410d | finish no earlier than 2006-12-15 | RP | 1584h | 158.4h | RANFS-HSPAEvo | don.zelmer@cingular.com | Rel-7 | MCC_RAN |  |  |

Notes:
- 317: Moved from FS section Feb 06 / Text4: Peter Bleckert, Ericsson
- 318: Text4: Peter Bleckert, Ericsson
- 319: Text4: Peter Bleckert, Ericsson
- 320: Approved at SP#29. To be shown as feature - END Sept 06 / Text4: Stephen Terrill (Ericsson)
- 321: The WID still calls it a BB, not a Feature. / Text4: D Williams (QUALCOMM)
- 324: Text4: Mark Watson (Nortel Networks)
- 325: S2#52: Split into Study and Specification phases. / Text4: Osok Song (Samsung)
- 326: S2#52: Entry created / Text4: Donghee Shim (LG Electronics Inc.); Patrice HÉDÉ (LG Electronics Mobilecomm France)
- 327: Text4: Mike Vogel
- 328: Text4: Takehiro Nakamura (NTT DoCoMo)
- 329: Text4: Kurt Bischinger (T-Mobile)
- 330: Text4: Kurt Bischinger (T-Mobile)
- 331: Text4: Chris Friel (O2)
- 332: Text4: Chris Friel (O2)
- 333: Text4: Joerg Gustrau
- 334: Text4: Klas Sjerling
- 335: Moved from Rel6 / Text4: Jim Garrahan (Telcordia)
- 336: Text4: Steve Vardy, (Motorola S.A.S)
- 337: Study WI / Text4: Nick Russell, Vodafone UK
- 338: Text4: YoungDae Lee, LG
- 339: Text4: Marc Grant, Cingular
- 340: Text4: Marc Grant, Cingular
- 341: Study WI / TR presented for information in CT#30 / Text4: Ulrich Wiehe, Siemens
- 342: Awaiting MCC SA3 input; No input from SA3 at this time / Text4: Feng Lingjuan, China Mobile
- 343: Text4: Don Zelmer

| ID | WBS | Task | Type | Duration | Start | Finish | Complete | Remaining | Baseline start | Baseline finish | Baseline duration | Total slack | Constraint | Resources | Work | Actual work | Text1 | Text4 | Text5 | Text6 | Text7 | Text8 | Text12 | Text3 |
| --- | --- | --- | --- | --- | --- | --- | --- | --- | --- | --- | --- | --- | --- | --- | --- | --- | --- | --- | --- | --- | --- | --- | --- | --- |
| 344 | 106 | **OAM&P Studies** |  | 336d? | 2005-09-02 A | 2006-12-15 | 29% | 238.9d? | 2005-09-02 | 2006-12-15 | 336d? | 410d |  | S5 | 21224h | 7663.72h | OAM7-Study | Christian TOCHE | Christian.Toche@huawei.com | Rel-7 | TSG | Adrian |  |  |
| 345 | 106.1 | **Deleted - Network Infrastructure Management** |  | 336d? | 2005-09-02 A | 2006-12-15 | 31% | 232.64d? | 2005-09-02 | 2006-12-15 | 336d? | 410d |  | S5 | 17576h | 4975.72h | OAM7-NIM |  |  | Rel-7 |  |  | SP-32 |  |
| 346 | 106.1.1 | Deleted - IRP usage scenarios (Study) |  | 336d? | 2005-09-02 | 2006-12-15 |  |  | 2005-09-02 | 2006-12-15 | 336d? | 410d | finish no earlier than 2006-12-15 | S5 | 2688h |  | OAM7-NIM | Lucent |  | Rel-7 |  |  | SP-32 | new TR 32.8xy |
| 347 | 106.1.2 | Deleted - Study of Element Operations Systems Function (EOSF) definition |  | 336d? | 2005-09-02 A | 2006-12-15 | 35% | 218.4d? | 2005-09-02 | 2006-12-15 | 336d? | 410d | finish no earlier than 2006-12-15 | S5 | 2688h | 940.8h | OAM7-NIM- EOSF | China Mobile |  | Rel-7 |  |  | SP-32 | new TR 32.8xy |
| 348 | 106.1.3 | Deleted - Study of SOAP/HTTP IRP Solution Sets |  | 336d? | 2005-09-02 A | 2006-12-15 | 25% | 252d? | 2005-09-02 | 2006-12-15 | 336d? | 410d | finish no earlier than 2006-12-15 | S5 | 2688h | 672h | OAM7-NIM-SOAP | Nortel |  | Rel-7 |  |  | SP-32 | new TR 32.8xy |
| 349 | 106.1.4 | Deleted - Study of Itf-N Implementation Conformance Statement (ICS) template |  | 336d? | 2005-09-02 A | 2006-12-15 | 45% | 184.8d? | 2005-09-02 | 2006-12-15 | 336d? | 410d | finish no earlier than 2006-12-15 | S5 | 2688h | 1209.6h | OAM7-NIM-ICS | China Mobile |  | Rel-7 |  |  | SP-32 | new TR 32.8xy |
| 350 | 106.1.5 | Deleted - Study of IRP Information Model |  | 336d? | 2005-09-02 A | 2006-12-15 | 60% | 134.4d? | 2005-09-02 | 2006-12-15 | 336d? | 410d | finish no earlier than 2006-12-15 | S5 | 2688h | 1612.8h | OAM7-NIM-IM | Motorola |  | Rel-7 |  |  | SP-32 | new TR 32.8xy |
| 351 | 106.1.6 | Deleted - Study on SA5 MTOSI XML Harmonization |  | 181d? | 2006-04-07 A | 2006-12-15 | 10% | 162.9d? | 2006-04-07 | 2006-12-15 | 181d? | 410d | finish no earlier than 2006-12-15 | S5 | 1448h | 144.8h | OAM7-NIM-XML | Nortel |  | Rel-7 |  |  | SP-32 | new TR 32.8xy |
| 352 | 106.1.7 | Delete - was duplicated - Study on SA5 MTOSI XML Harmonization | milestone | 0d? | 2006-12-15 A | 2006-12-15 A | 100% |  | 2006-04-07 | 2006-12-15 | 181d? |  | start no earlier than 2006-12-15 | S5 |  |  | OAM7-NIM-XML | Nortel |  | Rel-7 |  |  | SP-30 | new TR 32.8xy |
| 353 | 106.2 | Study of Common Profile Storage (CPS) Framework of User Data for network services and management |  | 120d? | 2006-07-03 | 2006-12-15 |  |  |  |  |  | 410d | finish no earlier than 2006-12-15 | S5 | 960h |  | OAM7-CPS | T-Mobile |  | Rel-7 |  |  |  | new TR 32.8xy |
| 354 | 107 | SI on AS-MRFC media server control protocol |  | 253d? | 2006-03-22 A | 2007-03-09 | 10% | 227.7d? | 2006-03-22 | 2006-09-22 | 133d? | 350d | finish no earlier than 2007-03-09 | C1 | 2024h | 202.4h | MRFC | Mark Syrett (Hewlett-Packard) |  | Rel-7 |  |  |  | New TR 24.880 |
| 355 | 108 | Study on IMS utilizing multicast bearer services |  | 193d? | 2006-03-22 A | 2006-12-15 | 20% | 154.4d? | 2006-03-22 | 2006-12-15 | 193d? | 410d | finish no earlier than 2006-12-15 | S2 | 1544h | 308.8h | FS-MLTICAST-IMS | Fiona Zhu (Siemens AG) |  |  |  | Maurice |  | 23.847 |
| 356 | 109 | FS of using M2PA in 3GPP network |  | 193d? | 2006-03-22 | 2006-12-15 |  |  | 2006-03-22 | 2006-12-15 | 193d? | 410d | start no earlier than 2006-03-22 | C4 | 1544h |  | FS-M2PA |  |  |  |  | Kimmo |  |  |
| 357 | 110 | Enhancement of E2E QoS |  | 336.4d? | 2004-06-28 A | 2005-12-01 A | 100% |  | 2004-06-28 | 2005-12-01 | 336.4d? |  | finish no earlier than 2005-12-01 | S2 | 2691.2h | 2691.2h | QoS7 |  |  | Rel-7 | TSG | Maurice |  | 23.802 |
| 358 | 111 | Bandwidth Saving at Nb Interface with IP transport |  | 126d? | 2006-03-10 A | 2006-09-01 | 40% | 75.6d? | 2006-03-10 | 2006-09-01 | 126d? | 485d | finish no earlier than 2006-09-01 | C3 | 1008h | 403.2h | BSNbIP | Thomas BELLING(Siemens) | thomas.belling@siemens.com | Rel-7 |  | Seung Don |  | 29.414, 29.415 |
| 359 | 112 | **3GPP System Architecture Evolution** |  | 526d? | 2004-12-03 A | 2006-12-08 | 69% | 161.42d? | 2004-12-03 | 2006-12-08 | 526d? | 415d |  | S2 | 8504h | 5894.2h | SAE |  |  | Rel-7 | TSG |  |  |  |
| 360 | 112.1 | Stage 2 Interim conclusion for RAN Work to start |  | 211d? | 2004-12-03 A | 2005-09-23 A | 100% |  | 2004-12-03 | 2005-09-23 | 211d? |  | finish no earlier than 2005-09-23 | S2 | 1688h | 1688h |  |  |  | Rel-7 |  |  |  | 23.882 |
| 361 | 112.2 | Stage 2 Feasibility study on 3GPP architectural development |  | 240d? | 2006-01-09 A | 2006-12-08 | 60% | 96d? | 2006-01-09 | 2006-12-08 | 240d? | 415d | finish no earlier than 2005-09-23 | S2 | 1920h | 1152h |  | Osok Song (Samsung) | osok.song@samsung.com | Rel-7 |  | Maurice |  | 23.819 |
| 362 | 112.3 | Security study for Inter-access mobility between non 3GPP and 3GPP system |  | 86d? | 2006-02-03 A | 2006-06-02 | 20% | 68.8d? | 2006-02-03 | 2006-06-02 | 86d? | 550d | start no earlier than 2006-02-03 | S3 | 688h | 137.6h | SAE-Sec |  |  | Rel-7 |  |  |  | 23.882 |
| 363 | 112.4 | Deleted - Duplicateed with 32087 - Stage 2 Feasibility study on 3GPP architectural development | milestone | 0d? | 2006-09-27 A | 2006-09-27 A | 100% |  | 2004-12-03 | 2006-09-27 | 474d? |  | start no earlier than 2006-09-27 | S2 |  |  |  |  |  | Rel-7 |  |  | SP-32 | 23.882 |
| 364 | 113 | FS WID on Support of (G)MSC-S - (G)MSC-S Nc Interface based on the SIP-I protocol |  | 155d? | 2006-05-15 A | 2006-12-15 | 10% | 139.5d? |  |  |  | 410d | finish no earlier than 2006-12-15 | C4 | 1240h | 124h | NcSIP | David Hutton, Vodafone Group | david.hutton@vodafone.com | Rel-7 |  | Kimmo |  | 29.802 |
| 365 | 114 | deleted - covered by UID33027 - IMS security extensions | milestone | 0d? | 2005-12-08 A | 2005-12-08 A | 100% |  | 2005-06-28 | 2005-12-08 | 118d? |  | start no earlier than 2005-12-08 | S3 |  |  | IMS-SE | Bengt Sahlin, Ericsson | Bengt.Sahlin@ericsson.com | Rel-7 |  | Mike | SP-30 |  |
| 366 | 115 | **Deleted: FS on applicability of GALILEO for LCS** |  | 484d? | 2003-08-25 A | 2005-06-30 A | 100% |  | 2003-08-25 | 2005-06-30 | 484d? |  |  | S2 | 3872h | 3872h | Galileo |  |  | Rel-7 |  |  | SP-25 |  |
| 367 | 115.1 | Deleted - TR on Stage 2 | milestone | 0d? | 2005-06-30 A | 2005-06-30 A | 100% |  | 2005-06-30 | 2005-06-30 | 0d? |  | finish no earlier than 2005-06-30 | S2 |  |  |  |  |  | Rel-7 |  |  | SP-25 |  |
| 368 | 115.2 | deleted - GERAN review of the TR | milestone | 0d? | 2003-08-25 A | 2003-08-25 A | 100% |  | 2003-08-25 | 2003-08-25 | 0d? |  | finish no earlier than 2003-08-25 | GP |  |  |  |  |  | Rel-7 |  |  | SP-26 |  |

Notes:
- 357: Moved to a FS as SA32 (in line with slides)
- 358: Moved to FS at CT32 (in line with slides)
- 360: RAN work started
- 361: S2#52: Study phase created
- 364: Study WI

| ID | WBS | Task | Type | Duration | Start | Finish | Complete | Remaining | Baseline start | Baseline finish | Baseline duration | Total slack | Constraint | Resources | Work | Actual work | Text1 | Text3 | Text6 | Text12 | Text4 | Text5 | Text7 | Text8 |
| --- | --- | --- | --- | --- | --- | --- | --- | --- | --- | --- | --- | --- | --- | --- | --- | --- | --- | --- | --- | --- | --- | --- | --- | --- |
| 369 | 16.7 | **Deleted - IMS Local services** |  | 984d? | 2002-03-29 A | 2006-01-06 A | 100% |  | 2001-01-01 | 2005-06-08 | 1158d? |  |  | S2 | 7872h | 7872h | IMSLocal | 23.228 | Rel-7 | SP-28 |  |  |  |  |
| 370 | 16.7.1 | Deleted - Stage 2 | milestone | 0d | 2002-03-29 A | 2002-03-29 A | 100% |  | 2001-01-01 | 2002-03-29 | 325d |  | start no earlier than 2002-03-29 | S2 |  |  |  |  | Rel-7 | SP-26 |  |  |  |  |
| 371 | 116.2 | Delete - Stage 3 for IMS Local services | milestone | 0d? | 2006-01-06 A | 2006-01-06 A | 100% |  | 2004-11-10 | 2005-06-08 | 151d? |  | finish no earlier than 2006-01-06 | C1 |  |  |  |  | Rel-7 | SP-25 | Keith Drage, Lucent | drage@lucent.com |  |  |
| 372 | 117 | Deleted - IMS Phase 3 | milestone | 0d? | 2005-06-08 A | 2005-06-08 A | 100% |  | 2005-06-08 | 2005-06-08 | 0d? |  | finish no earlier than 2005-06-08 | S2 |  |  |  |  | Rel-7 | SP-25 |  |  |  |  |
| 373 | 118 | Deleted - Improvements of Radio Interface | milestone | 0d? | 2004-09-15 A | 2004-09-15 A | 100% |  | 2004-09-15 | 2004-09-15 | 0d? |  | start no earlier than 2004-09-15 | RP |  |  | RInImp |  | Rel-7 | SP-24 |  | Rel-7 | TSG | Cesar |
| 374 | 119 | **Deleted: Generic User Profile Phase 2** |  | 234.4d | 2004-11-12 A | 2005-10-06 A | 100% |  | 2005-10-06 | 2006-08-31 | 234.4d |  |  | C4 |  |  |  |  | Rel-7 | SP-27 |  |  |  | Gaby |
| 375 | 30.4 | Deleted - Stage 3 - Common objects | milestone | 0d | 2004-11-12 A | 2005-10-06 A | 100% |  | 2005-10-06 | 2006-08-31 | 0d |  | finish no earlier than 2005-10-06 | C4 |  |  |  | 24.241 | Rel-7 | SP-27 |  |  | TSG | Gaby |
| 376 | 120 | Delete was duplicated- Study of Customised Alerting Tone (CAT) Requirements | milestone | 0d? | 2006-06-30 A | 2006-06-30 A | 100% |  | 2005-10-07 | 2006-06-30 | 191d? |  | start no earlier than 2006-06-30 | S1 |  |  | CAT |  | Rel-7 | SP-31 |  |  |  |  |
| 377 | 121 | Delete - was duplicated - Facilitating Machine to Machine Communication in GSM and UMTS (M2M) | milestone | 0d? | 2006-06-16 A | 2006-06-16 A | 100% |  | 2005-11-04 | 2006-06-16 | 161d? |  | start no earlier than 2006-06-16 | S1 |  |  | M2M | 22.868 | Rel-7 | SP-32 | Juergen Merkel, Siemens AG |  |  | Michael |
| 378 | 122 | Deleted - FS of enhanced support of Video Telephony | milestone | 0d? | 2006-06-30 A | 2006-06-30 A | 100% |  | 2004-08-27 | 2006-06-30 | 481d? |  | start no earlier than 2006-06-30 | GP |  |  | VIDGER |  | Rel-7 | SP-32 | Stefan Eriksson, Ericsson | stefan.g.eriksson@ericsson.com | TSG | Paolo |
| 379 | 123 | Release 8 Features |  | 1d? | 2000-01-03 | 2000-01-03 |  |  | 2000-01-03 | 2000-01-03 | 1d? | 2224d |  | CT;RAN;SA | 8h |  |  |  | Rel-8 |  |  |  |  |  |
| 380 | 124 | **Enhancements for VGCS Applications** |  | 243d? | 2006-03-15 A | 2007-02-16 | 27% | 176.59d? | 2006-03-15 | 2006-12-06 | 191d? | 365d |  | S1 | 6976h | 1528h | EVA | 42.068 | Rel-8 |  | Amar Deol, Nortel Networks | deola@nortel.com |  | Michael |
| 381 | 124.1 | SA1 aspects for EVA |  | 191d? | 2006-03-15 A | 2006-12-06 | 90% | 19.1d? | 2006-03-15 | 2006-12-06 | 191d? | 417d | finish no earlier than 2006-12-06 | S1 | 1528h | 1375.2h |  | 42.068 | Rel-8 |  | Amar Deol, Nortel Networks | deola@nortel.com |  | Michael |
| 382 | 124.2 | C1 asptects for EVA |  | 136d? | 2006-06-02 | 2006-12-08 |  |  |  |  |  | 415d | finish no earlier than 2006-12-08 | C1 | 1088h |  |  | 43.068, 44.068 | Rel-8 |  | Milan Patel | milanpa@nortel.com |  | Andrijana |
| 383 | 124.3 | C4 aspects for EVA |  | 136d? | 2006-06-02 | 2006-12-08 |  |  |  |  |  | 415d | finish no earlier than 2006-12-08 | C4 | 1088h |  |  | 29.002 | Rel-8 |  |  |  |  | Kimmo |
| 384 | 124.4 | GERAN2 Aspects of EVA |  | 166d? | 2006-06-30 | 2007-02-16 |  |  |  |  |  | 365d | finish no earlier than 2007-02-16 | G2 | 1328h |  | EVA-EVGCSA | 44.018, 48.008 | Rel-8 |  | Frank Billenkamp (Notrtel Networks) | frank.billenkamp@nortel.com |  | Gert |
| 385 | 125 | **IMS Service Brokering enhancements** |  | 69d? | 2005-12-07 A | 2006-03-13 A | 100% |  | 2005-12-07 | 2006-03-13 | 69d? |  |  | S1 | 1104h | 1104h | ISB | 22.228 | Rel-8 |  | John-Luc Bakker (Telcordia) | jbakker@telcordia.com |  | Michael |
| 386 | 125.1 | Stage 1 of ISB |  | 69d? | 2005-12-07 A | 2006-03-13 A | 100% |  | 2005-12-07 | 2006-03-13 | 69d? |  | finish no earlier than 2006-03-13 | S1 | 552h | 552h |  | 22.228 | Rel-8 |  | John-Luc Bakker (Telcordia) | jbakker@telcordia.com |  | Michael |
| 387 | 126 | **3GPP System Architecture Evolution Specification** |  | 157d? | 2006-06-08 | 2007-01-12 |  |  | 2006-05-15 | 2006-12-08 | 150d? | 390d |  | S2 | 3768h |  | SAES | 23.228, 23.279 | Rel-8 |  | Osok Song (Samsung) | osok.song@samsung.com |  | Maurice |
| 388 | 126.1 | Requirements for evolution of the 3GPP system architecture |  | 157d? | 2006-06-08 | 2007-01-12 |  |  |  |  |  | 390d | finish no earlier than 2007-01-12 | S1 | 1256h |  | AIPN-SAE | 22.278 | Rel-8 |  | Michael Kurz (T-Mobile International) | michael.kurz@t-mobile.at |  | Michael |
| 389 | 126.2 | Architectural aspects of SAES |  | 157d? | 2006-06-08 | 2007-01-12 |  |  |  |  |  | 390d | start no earlier than 2006-06-08 | S2 | 1256h |  | SAES | 23.228, 23.279 | Rel-8 |  | Osok Song (Samsung) | osok.song@samsung.com |  | Maurice |
| 390 | 127 | (Small) Technical Enhancements and Improvements for Rel-8 |  | 400d? | 2007-01-01 | 2008-07-11 |  |  | 2005-06-06 | 2006-12-15 | 400d? | 0d | start no earlier than 2007-01-01 | All | 3200h |  | TEI8 |  | Rel-8 |  |  |  |  |  |
| 391 | 128 | Rel-8 Feasibility Studies |  | 1d? | 2000-01-03 | 2000-01-03 |  |  | 2000-01-03 | 2000-01-03 | 1d? | 2224d |  | CT;RAN;SA | 8h |  |  |  | Rel-8 |  |  |  |  |  |
| 392 | 129 | Facilitating Machine to Machine Communication in GSM and UMTS (M2M) |  | 161d? | 2005-11-04 A | 2006-06-16 | 60% | 64.4d? | 2005-11-04 | 2006-06-16 | 161d? | 540d | finish no earlier than 2006-06-16 | S1 | 1288h | 772.8h | M2M | 22.868 | Rel-8 |  | Juergen Merkel, Siemens AG |  |  | Michael |

Notes:
- 370: DAB - Not yet required in SA2 as it exists in previous releases
- 373: Stage 2 description of Interim conclusion
- 374: Created at TSG#27 by A. Sultan because of the move to Rel-7 of "Common Objects".
- 375: No progress in CN4#26. This have to be moved to Rel-7. It was deleted from WID
- 376: Awaiting MCC SA3 input
- 378: FS CLOSED at G#28 (no input)
- 387: S2#52: Specification phase created. New WID approved SA#32
- 388: Moved to SA2 at SA#32
- 389: S2#52: Specification phase created. New WID approved SA#32

| ID | WBS | Task | Duration | Start | Finish | Complete | Remaining | Baseline start | Baseline finish | Baseline duration | Total slack | Constraint | Resources | Work | Actual work | Text1 | Text3 | Text4 | Text5 | Text6 | Text7 | Text8 |
| --- | --- | --- | --- | --- | --- | --- | --- | --- | --- | --- | --- | --- | --- | --- | --- | --- | --- | --- | --- | --- | --- | --- |
| 393 | 130 | **All-IP Network (AIPN)** | 448d? | 2004-06-28 A | 2006-03-15 A | 100% |  | 2004-06-28 | 2006-03-15 | 448d? |  |  | S1 | 8672h | 8672h | AIPN | 22.978 | Chris Sachno (NTT DoCoMo) | c.masyu@nttdocomo.co.jp | Rel-8 | TSG | Michael |
| 394 | 130.1 | All-IP Network Feasibility Study | 188d? | 2004-06-28 A | 2005-03-16 A | 100% |  | 2004-06-28 | 2005-03-16 | 188d? |  | start no earlier than 2004-06-28 | S1 | 1504h | 1504h | AIPFS | 22.978 | Chris Sachno (NTT DoCoMo) | c.masyu@nttdocomo.co.jp | Rel-8 | TSG | Michael |
| 395 | 130.2 | Stage1 | 448d? | 2004-06-28 A | 2006-03-15 A | 100% |  | 2004-06-28 | 2006-03-15 | 448d? |  | finish no earlier than 2006-03-15 | S1 | 3584h | 3584h | AIPN | 22.258 | Chris Sachno (NTT DoCoMo) | c.masyu@nttdocomo.co.jp | Rel-8 | TSG | Michael |
| 396 | 131 | Study on Stage 2 aspects of IMS Service Brokering | 265d? | 2006-06-19 | 2007-06-22 |  |  |  |  |  | 275d | start no earlier than 2006-06-19 | S2 | 2120h |  | ISB_ST2_SDY | 23.810 | John-Luc Bakker (Telcordia) | jbakker@telcordia.com | Rel-8 |  | Maurice |
| 397 | 132 | Multimedia Priority Service in Emergency Situations | 157d? | 2006-06-08 A | 2007-01-12 | 20% | 125.6d? | 2003-03-28 | 2006-06-30 | 851d? | 390d | finish no earlier than 2007-01-12 | S1 | 1256h | 251.2h | PRIOR-EMR | 22.2xx | Jim Garrahan (Telcordia) | jgarraha@telcordia.com | Rel-8 |  | Michael |
| 398 | 133 | Study of Requirements of IP-Multimedia Subsystem (IMS) Multimedia Conferencing | 205d? | 2006-06-08 A | 2007-03-21 | 10% | 184.5d? |  |  |  | 342d | finish no earlier than 2007-03-21 | S1 | 1640h | 164h | SI-IMSconf | 22.948 | Zheng Jianping (China Mobile ) | zhengjianping@chinamobile.com | Rel-8 |  | Michael |
| 399 | 134 | Study on support of a Public Warning System (PWS) | 205d? | 2006-06-08 A | 2007-03-21 | 10% | 184.5d? |  |  |  | 342d | start no earlier than 2006-06-08 | S1 | 1640h | 164h | PWS-SI | 22.968 | Frederic Thepot (NTT DoCoMo Inc.) | thepot@docomolab-euro.com | Rel-8 |  | Michael |
| 400 | 135 | Consumer protection against spam and malware | 205d? | 2006-06-08 | 2007-03-21 |  |  |  |  |  | 342d | start no earlier than 2006-06-08 | S3 | 1640h |  | CPSMal | 33.9xx | Eric Gauthier (Orange SA) | eric.gauthier@orange.ch | Rel-8 |  | Michael |
| 401 | 136 | Study of VCC support for Emergency Calls | 207d? | 2006-06-08 | 2007-03-23 |  |  |  |  |  | 340d | finish no earlier than 2007-03-23 | S2 | 1656h |  | FSVCCEm | 23.8xx | Bob Beeson, Lucent |  | Rel-8 |  | Maurice |

Notes:
- 396: Study approved SA#32
- 397: -
